# Dorado2002revB

How a schedule from MS Project changed from version to version. A marks actual dates.

## Version 1 (saved 2002-04-30, file Dorado2002revB.mpp)

| ID | WBS | Task | Duration | Start | Finish | Predecessors | Complete | Total float | Constraint |
| --- | --- | --- | --- | --- | --- | --- | --- | --- | --- |
| 1 | 1 | **Dorado Program** | 235d? | 2002-03-15 A | 2003-02-06 |  |  | 0d |  |
| 3 | 1.1 | **Propulsion** | 127d | 2002-03-15 | 2002-09-09 |  |  | 51d |  |
| 4 | 1.1.1 | **Articulated Tail** | 10d | 2002-03-15 | 2002-03-28 |  |  | 164d |  |
| 5 |  | Design & Build New Electronics Housing | 10d | 2002-03-15 | 2002-03-28 |  |  | 164d |  |
| 6 |  | New Linear Actuator Scheme | 7d | 2002-03-15 | 2002-03-25 |  |  | 167d |  |
| 7 | 1.1.2 | **Drive Electronics** | 24d | 2002-03-15 | 2002-04-17 |  |  | 148d |  |
| 8 |  | Integrate New Electroincs | 24d | 2002-03-15 | 2002-04-17 |  |  | 148d | start no earlier than 2002-03-15 |
| 9 |  | Cabling | 5d | 2002-03-28 | 2002-04-03 |  |  | 158d | start no earlier than 2002-03-28 |
| 10 |  | Integrate New Tail Into fairing | 5d | 2002-04-18 | 2002-04-24 | 7 |  | 148d |  |
| 11 |  | Tailcone - Bench Stand Design and Fab | 3d | 2002-03-15 | 2002-03-19 |  |  | 175d |  |
| 12 |  | Buoyancy Check / Test | 1d | 2002-04-25 | 2002-04-25 | 10 |  | 148d |  |
| 13 |  | Test Plan | 5d | 2002-04-08 | 2002-04-12 |  |  | 157d | start no earlier than 2002-04-08 |
| 14 | 1.1.7 | **Tailcone Documetation** | 103d | 2002-04-18 | 2002-09-09 | 7, 4 |  | 51d |  |
| 15 |  | Mechanical | 3d | 2002-04-18 | 2002-04-22 |  |  | 151d |  |
| 16 |  | Electrical | 2d | 2002-09-02 | 2002-09-03 |  |  | 55d | start no earlier than 2002-09-02 |
| 17 |  | Software | 4d | 2002-09-04 | 2002-09-09 |  |  | 51d | start no earlier than 2002-09-04 |
| 19 | 1.2 | **Power** | 49d? | 2002-03-15 | 2002-05-22 |  |  | 139d |  |
| 20 | 1.2.1 | **Battery Chemistry** | 27d | 2002-03-15 | 2002-04-22 |  |  | 139d |  |
| 21 |  | Check life on current Ag-Zn batteries | 2d | 2002-03-15 | 2002-03-18 |  |  | 142d |  |
| 22 |  | Trade study to review Batt Chems | 2d | 2002-03-15 | 2002-03-18 |  |  | 142d |  |
| 23 |  | Thermal Analysis of Battery Pack | 5d | 2002-03-15 | 2002-03-21 |  |  | 139d |  |
| 24 |  | Design Review of Batt Chems | 1d | 2002-03-22 | 2002-03-22 | 21, 22, 23 |  | 139d |  |
| 25 |  | Purchase Batteries | 1d | 2002-03-25 | 2002-03-25 | 24 |  | 205d |  |
| 26 |  | Assemble Batteries | 5d | 2002-03-26 | 2002-04-01 | 25 |  | 205d |  |
| 27 |  | Test Batteries | 15d | 2002-04-02 | 2002-04-22 | 26 |  | 205d |  |
| 28 | 1.2.2 | **Battery Housing** | 30d | 2002-03-25 | 2002-05-03 | 24 |  | 199d |  |
| 29 |  | Design | 10d | 2002-03-25 | 2002-04-05 |  |  | 199d |  |
| 30 |  | Build | 15d | 2002-04-08 | 2002-04-26 | 29 |  | 199d |  |
| 31 |  | Test | 5d | 2002-04-29 | 2002-05-03 | 30 |  | 199d |  |
| 32 |  | Spec Interconnects | 4d | 2002-03-25 | 2002-03-28 |  |  | 202d | finish no earlier than 2002-03-25 |
| 33 | 1.2.3 | **Battery Electronics** | 21d? | 2002-04-22 | 2002-05-20 | 24, 32 |  | 186d |  |
| 34 |  | Concept Design | 5d | 2002-04-22 | 2002-04-26 |  |  | 186d | start no earlier than 2002-04-22 |
| 35 |  | Design Review | 2d | 2002-04-29 | 2002-04-30 | 34 |  | 186d |  |
| 36 |  | Final Design | 11d | 2002-05-01 | 2002-05-15 | 35 |  | 186d | start no earlier than 2002-05-01 |
| 37 |  | Build | 1d | 2002-05-16 | 2002-05-16 | 36 |  | 186d |  |
| 38 |  | Assemble | 1d | 2002-05-17 | 2002-05-17 | 37 |  | 186d |  |
| 39 |  | Test | 1d | 2002-05-20 | 2002-05-20 | 38 |  | 186d |  |
| 40 |  | Spec Misc Electronics (Contingency) | 1d? | 2002-04-26 | 2002-04-26 | 27 |  | 202d | start no earlier than 2002-04-26 |
| 41 | 1.2.4 | **Battery Charging** | 2d | 2002-05-21 | 2002-05-22 | 24, 33 |  | 186d |  |
| 42 |  | Spec Charging Analysis | 2d | 2002-05-21 | 2002-05-22 |  |  | 186d |  |
| 43 |  | Order Charging Equip as Required | 1d | 2002-05-21 | 2002-05-21 |  |  | 187d |  |
| 44 |  | AUV Power Systems Meeting | 3d | 2002-04-26 | 2002-04-30 |  |  | 202d | start no earlier than 2002-04-26 |
| 46 | 1.3 | **Cabling and Connectors** | 24d | 2002-03-25 | 2002-04-25 | 24 |  | 148d |  |
| 47 |  | Spec Main Power / Comms Cable&Connectors/Penetrators | 13d | 2002-03-25 | 2002-04-10 |  |  | 148d |  |
| 48 |  | Spec Charging Connector | 4d | 2002-04-11 | 2002-04-16 | 47 |  | 155d |  |
| 49 |  | Spec Tailcone Comms Cable&Connector/Penetrator | 3d | 2002-03-25 | 2002-03-27 |  |  | 158d | start no earlier than 2002-03-18 |
| 50 |  | Spec Science Instrument Connector | 2d | 2002-03-25 | 2002-03-26 |  |  | 156d |  |
| 51 |  | Spec DVL and parosci Connectors / Penetrator | 1d | 2002-03-27 | 2002-03-27 | 50 |  | 156d |  |
| 52 |  | Spec RF/Acoustic/Emer location Connect & Penetrators | 1d | 2002-03-28 | 2002-03-28 | 51 |  | 156d |  |
| 53 |  | Spec On/Off Connector/Penetrator | 1d | 2002-03-29 | 2002-03-29 | 52 |  | 156d |  |
| 54 |  | Test ability of 100 MB/s thrugh current ALTEX Cable | 2d | 2002-03-25 | 2002-03-26 |  |  | 170d |  |
| 55 |  | Order Connectors | 1d | 2002-04-11 | 2002-04-11 | 47, 49, 53 |  | 148d |  |
| 56 | 1.3.10 | **Tail to MVC** | 1d | 2002-03-25 | 2002-03-25 |  |  | 161d |  |
| 57 |  | Section Interconnect | 1d | 2002-03-25 | 2002-03-25 |  |  | 161d |  |
| 58 |  | Documetation package on Connectors and Cabling | 10d | 2002-04-12 | 2002-04-25 | 55, 57 |  | 148d |  |
| 60 | 1.4 | **Main Vehicle Computer** | 39d | 2002-03-15 A | 2002-05-08 |  | 3% | 139d |  |
| 61 | 1.4.1 | **Electronics** | 29d | 2002-03-15 A | 2002-04-24 |  | 4% | 149d |  |
| 62 |  | Spec PC 104 Stack | 2d | 2002-03-15 A | 2002-03-18 A |  | 100% |  |  |
| 63 |  | Order PC 104 Stack | 1d | 2002-03-19 A | 2002-03-19 A | 62 | 100% |  |  |
| 64 |  | Assemble PC 104 Stack | 2d | 2002-03-20 | 2002-03-21 | 63 |  | 173d |  |
| 65 |  | Develop latency test/budget for MVC | 4d | 2002-04-11 | 2002-04-16 |  |  | 155d | finish no earlier than 2002-04-16 |
| 66 | 1.4.1.5 | **Power Board** | 23d | 2002-03-25 | 2002-04-24 | 24 |  | 139d |  |
| 67 |  | Specify | 4d | 2002-03-25 | 2002-03-28 |  |  | 139d |  |
| 68 |  | Design | 15d | 2002-03-29 | 2002-04-18 | 67 |  | 139d |  |
| 69 |  | Order | 1d | 2002-04-19 | 2002-04-19 | 68 |  | 139d |  |
| 70 |  | Build | 2d | 2002-04-22 | 2002-04-23 | 69 |  | 139d |  |
| 71 |  | Test | 1d | 2002-04-24 | 2002-04-24 | 70 |  | 139d |  |
| 72 | 1.4.1.6 | **RF Modem** | 6d | 2002-03-15 | 2002-03-22 |  |  | 172d |  |
| 73 |  | Evaluate Data-link vs Freewave | 5d | 2002-03-15 | 2002-03-21 |  |  | 172d |  |
| 74 |  | Purchase | 1d | 2002-03-22 | 2002-03-22 | 73 |  | 172d |  |

| ID | WBS | Task | Duration | Start | Finish | Predecessors | Total float | Constraint |
| --- | --- | --- | --- | --- | --- | --- | --- | --- |
| 75 | 1.4.1.7 | **Acoustic Modem** | 2d | 2002-03-15 | 2002-03-18 |  | 166d |  |
| 76 |  | Evaluate | 1d | 2002-03-15 | 2002-03-15 |  | 166d |  |
| 77 |  | Purchase | 1d | 2002-03-18 | 2002-03-18 | 76 | 166d |  |
| 78 | 1.4.1.8 | **GPS** | 15d | 2002-03-15 | 2002-04-04 |  | 153d |  |
| 79 |  | Evaluate GPS Position Fix Problem | 10d | 2002-03-15 | 2002-03-28 |  | 153d |  |
| 80 |  | Evaluate GPS Board & Antennae | 4d | 2002-03-29 | 2002-04-03 | 79 | 153d |  |
| 81 |  | Purchase GPS Board & Antennae | 1d | 2002-04-04 | 2002-04-04 | 80 | 153d |  |
| 82 |  | Eval and Purchase 10/100 Hub | 4d | 2002-03-20 | 2002-03-25 |  | 171d | start no earlier than 2002-03-20 |
| 83 |  | Eval & Purchase AHRS | 1d | 2002-03-15 | 2002-03-15 |  | 177d |  |
| 84 |  | Eval and Purchase LBL Board Set | 4d | 2002-03-15 | 2002-03-20 |  | 174d |  |
| 85 |  | Spec and Purcahse DVL | 5d | 2002-03-15 | 2002-03-21 |  | 173d |  |
| 86 | 1.4.2 | **MVC Housing** | 28d | 2002-03-15 | 2002-04-23 |  | 140d |  |
| 87 |  | Spec Interconnects | 6d | 2002-03-15 | 2002-03-22 |  | 140d |  |
| 88 |  | Design | 5d | 2002-03-25 | 2002-03-29 | 87 | 140d |  |
| 89 |  | Build/Purchase | 10d | 2002-04-01 | 2002-04-12 | 88 | 140d |  |
| 90 |  | Pressure Test | 2d | 2002-04-15 | 2002-04-16 | 89 | 140d |  |
| 91 |  | Electronics Packagin Layout | 5d | 2002-04-17 | 2002-04-23 | 90 | 140d |  |
| 92 | 1.4.3 | **Documentation Package** | 10d | 2002-04-25 | 2002-05-08 | 91, 78, 75, 66 | 139d |  |
| 93 |  | Mechanical | 2d | 2002-04-25 | 2002-04-26 |  | 145d |  |
| 94 |  | Electrical | 8d | 2002-04-25 | 2002-05-06 |  | 139d |  |
| 95 |  | Software | 2d | 2002-04-25 | 2002-04-26 |  | 145d |  |
| 96 |  | Integration | 2d | 2002-05-07 | 2002-05-08 | 94, 95, 93 | 139d |  |
| 98 | 1.5 | **Navigation Hardware & Testing** | 53d | 2002-03-15 | 2002-05-28 |  | 125d |  |
| 99 | 1.5.1 | **Deep Water testing of USBL** | 38d | 2002-03-15 | 2002-05-07 |  | 125d |  |
| 100 |  | Tank testing | 18d | 2002-03-15 | 2002-04-09 |  | 125d |  |
| 101 |  | At Sea Testing | 20d | 2002-04-10 | 2002-05-07 | 100 | 125d |  |
| 102 | 1.5.2 | **Deep Water Testing of LBL Fish Mode** | 15d | 2002-05-08 | 2002-05-28 | 99 | 125d |  |
| 103 |  | Tank Testing | 10d | 2002-05-08 | 2002-05-21 |  | 125d |  |
| 104 |  | At Sea Testing | 5d | 2002-05-22 | 2002-05-28 | 103 | 125d |  |
| 105 |  | Radio Range for modems | 3d | 2002-03-15 | 2002-03-19 |  | 175d |  |
| 106 |  | RDF Ranging | 3d | 2002-03-15 | 2002-03-19 |  | 174d |  |
| 107 |  | Eval Zephyr RDF capability | 1d | 2002-03-20 | 2002-03-20 | 106 | 174d |  |
| 109 | 1.6 | **Fairings / Vehicle Mechanical Structure** | 52d | 2002-03-15 | 2002-05-27 |  | 126d |  |
| 110 | 1.6.1 | **L&R System Interface** | 36d | 2002-03-15 | 2002-05-03 |  | 142d |  |
| 111 |  | Prelim Concept w/ Brook ocean | 5d | 2002-03-15 | 2002-03-21 |  | 142d |  |
| 112 |  | Concept Design Review / Decision | 1d | 2002-03-22 | 2002-03-22 | 111 | 142d |  |
| 113 |  | Design L&R Interface | 10d | 2002-03-25 | 2002-04-05 | 112 | 142d |  |
| 114 |  | Build Interface | 10d | 2002-04-08 | 2002-04-19 | 113 | 142d |  |
| 115 |  | Assemble Interface | 5d | 2002-04-22 | 2002-04-26 | 114 | 142d |  |
| 116 |  | L&R test plan | 4d | 2002-03-15 | 2002-03-20 |  | 169d |  |
| 117 |  | Integrate and Test L&R Interface | 5d | 2002-04-29 | 2002-05-03 | 116, 115 | 142d |  |
| 118 |  | Evaluate Single Point lift | 3d | 2002-03-26 | 2002-03-28 |  | 168d | start no earlier than 2002-03-26 |
| 119 | 1.6.2 | **Joining Ring/Systems** | 34d | 2002-03-15 | 2002-05-01 |  | 126d |  |
| 120 |  | Evaluate joining ring systems | 2d | 2002-03-15 | 2002-03-18 |  | 126d |  |
| 121 |  | Review Concept | 1d | 2002-03-19 | 2002-03-19 | 120 | 126d |  |
| 122 |  | Final Design | 15d | 2002-03-20 | 2002-04-09 | 121 | 126d |  |
| 123 |  | Build | 10d | 2002-04-10 | 2002-04-23 | 122 | 126d |  |
| 124 |  | Assemble | 3d | 2002-04-24 | 2002-04-26 | 123 | 126d |  |
| 125 |  | Test | 3d | 2002-04-29 | 2002-05-01 | 124 | 126d |  |
| 126 |  | Test new joining ring system | 3d | 2002-04-04 | 2002-04-08 |  | 143d | start no earlier than 2002-04-04 |
| 127 | 1.6.3 | **Deck Handling Equipment** | 10d | 2002-05-14 | 2002-05-27 | 141 | 126d |  |
| 128 |  | New Cart Design | 5d | 2002-05-14 | 2002-05-20 |  | 131d |  |
| 129 |  | New Lifitng Gear | 5d | 2002-05-14 | 2002-05-20 |  | 131d |  |
| 130 |  | Sphere Lift Mechanism | 10d | 2002-05-14 | 2002-05-27 |  | 126d |  |
| 131 |  | Eval Single Pt. Lift | 2d | 2002-05-14 | 2002-05-15 |  | 134d |  |
| 132 |  | Lifting I beam in Lab | 5d | 2002-05-14 | 2002-05-20 |  | 131d |  |
| 133 |  | Cable trays nad outlets in lab ceiling | 5d | 2002-05-14 | 2002-05-20 |  | 131d |  |
| 134 | 1.6.4 | **Sensor & Payload Mounts** | 4d | 2002-03-15 | 2002-03-20 |  | 156d |  |
| 135 |  | Antennaes | 4d | 2002-03-15 | 2002-03-20 |  | 156d |  |
| 136 |  | ORE & various equip | 4d | 2002-03-15 | 2002-03-20 |  | 156d |  |
| 137 | 1.6.5 | **Buoyancy** | 10d | 2002-03-15 | 2002-03-28 |  | 150d |  |
| 138 |  | Tailcone Foam Pack Specification | 5d | 2002-03-15 | 2002-03-21 |  | 150d |  |
| 139 |  | Tailcone foam machining | 5d | 2002-03-22 | 2002-03-28 | 138 | 150d |  |
| 140 |  | Modular trim / ballast systems concept | 5d | 2002-03-15 | 2002-03-21 |  | 155d |  |
| 141 | 1.6.6 | **Fairing Build** | 8d | 2002-05-02 | 2002-05-13 | 134, 137, 119 | 126d |  |
| 142 |  | Noes section (2 plus 1 spare) | 8d | 2002-05-02 | 2002-05-13 |  | 126d |  |
| 143 |  | Midboady (2 plus 1 spare) | 8d | 2002-05-02 | 2002-05-13 |  | 126d |  |
| 144 |  | Tail section (2 plus 1 spare) | 8d | 2002-05-02 | 2002-05-13 |  | 126d |  |
| 146 | 1.7 | **Software** | 178d | 2002-03-15 | 2002-11-19 |  | 0d |  |
| 147 |  | Change supervisor so drivers run all the time | 3d | 2002-09-02 | 2002-09-04 |  | 50d | start no earlier than 2002-09-02 |

| ID | WBS | Task | Duration | Start | Finish | Predecessors | Total float | Constraint |
| --- | --- | --- | --- | --- | --- | --- | --- | --- |
| 148 |  | Chang logging to convert files to MATLAB | 4d | 2002-09-05 | 2002-09-10 | 147 | 50d |  |
| 149 | 1.7.3 | **OS Upgrade** | 6d | 2002-03-15 | 2002-03-22 |  | 172d |  |
| 150 |  | QNX Upgrade to Neutrino | 3d | 2002-03-15 | 2002-03-19 |  | 172d |  |
| 151 |  | Eval Linux for possible upgrade in future | 3d | 2002-03-20 | 2002-03-22 | 150 | 172d |  |
| 152 | 1.7.4 | **GUI** | 50d | 2002-03-15 | 2002-05-23 |  | 128d |  |
| 153 |  | gather requirements | 5d | 2002-03-15 | 2002-03-21 |  | 128d |  |
| 154 |  | eval Bluefin GUI | 10d | 2002-03-22 | 2002-04-04 | 153 | 128d |  |
| 155 |  | develop GUI plan | 5d | 2002-04-05 | 2002-04-11 | 154 | 128d |  |
| 156 |  | Detail GUI development (TBD) | 30d | 2002-04-12 | 2002-05-23 | 155 | 128d |  |
| 157 |  | Configuration management on vehicle (config files) | 15d | 2002-03-15 | 2002-04-04 |  | 163d |  |
| 158 | 1.7.6 | **Controls** | 45d | 2002-03-15 | 2002-05-16 |  | 133d |  |
| 159 |  | depth control improvement (long configs) | 15d | 2002-03-15 | 2002-04-04 |  | 133d |  |
| 160 |  | sway / yaw control coupling (heave/ pitch too) | 10d | 2002-04-05 | 2002-04-18 | 159 | 133d |  |
| 161 |  | slow speed dynamics for control | 20d | 2002-04-19 | 2002-05-16 | 160 | 133d |  |
| 162 | 1.7.7 | **Navigation Software** | 42d | 2002-09-23 | 2002-11-19 |  | 0d |  |
| 163 |  | Document current NAV sys | 4d | 2002-09-23 | 2002-09-26 |  | 0d | start no earlier than 2002-09-23 |
| 164 |  | Streamline current nav architecture | 8d | 2002-09-27 | 2002-10-08 | 163 | 0d |  |
| 165 |  | Single beacon homing | 15d | 2002-10-09 | 2002-10-29 | 164 | 0d |  |
| 166 |  | Single beacon LBL | 15d | 2002-10-30 | 2002-11-19 | 165 | 0d |  |
| 167 |  | DVL driver enhancements for PD5 | 15d | 2002-10-09 | 2002-10-29 | 164 | 15d |  |
| 168 | 1.7.8 | **Intra-vehicle Comms** | 4d | 2002-10-01 | 2002-10-04 |  | 32d |  |
| 169 |  | set up socket code (for reconnects) | 3d | 2002-10-01 | 2002-10-03 |  | 32d | start no earlier than 2002-10-01 |
| 170 |  | briding over wireless | 1d | 2002-10-04 | 2002-10-04 | 169 | 32d |  |
| 172 | 1.8 | **Vehicle Integration and Test** | 35d | 2002-11-20 | 2003-01-07 | 3, 46, 109, 60, 98, 146 | 0d |  |
| 173 |  | Tailcone Assembly | 5d | 2002-11-20 | 2002-11-26 |  | 5d |  |
| 174 |  | Tailcone Test | 4d | 2002-11-27 | 2002-12-02 | 173 | 5d |  |
| 175 |  | Battery Midbody Integration | 5d | 2002-11-20 | 2002-11-26 |  | 5d |  |
| 176 |  | Battery Midbody Test | 4d | 2002-11-27 | 2002-12-02 | 175 | 5d |  |
| 177 |  | ALTEX Nose Payload Assembly/Upgrade | 5d | 2002-11-20 | 2002-11-26 |  | 0d |  |
| 178 |  | Science Payload Assembly | 6d | 2002-11-27 | 2002-12-04 | 177 | 0d | start no earlier than 2002-06-07 |
| 179 |  | Payload Test | 3d | 2002-12-05 | 2002-12-09 | 178 | 0d |  |
| 180 |  | Integrated Vehcile Deck Assembly | 2d | 2002-12-10 | 2002-12-11 | 174, 176, 179 | 0d |  |
| 181 |  | Vehicle Ballasting | 1d | 2002-12-12 | 2002-12-12 | 180 | 0d |  |
| 182 |  | Integrated Vehicle Deck Test | 3d | 2002-12-13 | 2002-12-17 | 181 | 0d |  |
| 183 |  | Integrated Vehicle Tank Test | 5d | 2002-12-18 | 2002-12-24 | 182 | 0d |  |
| 184 |  | Integrated Vehicle Sea Trials | 10d | 2002-12-25 | 2003-01-07 | 183 | 0d |  |
| 186 | 1.9 | **CTD Science Payload Core** | 214d? | 2002-03-15 | 2003-01-08 |  | 21d |  |
| 187 |  | Repair/Replace nose fairing | 3d | 2002-03-15 | 2002-03-19 |  | 175d |  |
| 188 |  | recable Dcon to comms and pwr bus | 8d | 2002-03-15 | 2002-03-26 |  | 151d |  |
| 189 |  | Design HS2 Mount | 2d | 2002-03-20 | 2002-03-21 | 187 | 175d |  |
| 190 |  | Build HS2 Mount | 2d | 2002-03-22 | 2002-03-25 | 189 | 175d |  |
| 191 |  | Assembly HS2 Mount | 2d | 2002-03-26 | 2002-03-27 | 190 | 175d |  |
| 192 |  | Write test driver HS2 | 5d | 2002-03-15 | 2002-03-21 |  | 179d |  |
| 193 |  | Eval Foam buoyancy cooridnate 1500 M version | 5d | 2002-03-15 | 2002-03-21 |  | 179d |  |
| 194 |  | repair flow sensor #2 | 3d | 2002-03-27 | 2002-03-29 | 188 | 151d |  |
| 195 |  | test integrated CTD Payload | 1d? | 2003-01-08 | 2003-01-08 | 194, 172 | 0d |  |
| 197 | 1.10 | **CTD Extension for Ryan/Haddock** | 21d | 2003-01-09 | 2003-02-06 | 194, 146, 195 | 0d |  |
| 198 |  | Design LISST pump assy | 4d | 2003-01-09 | 2003-01-14 |  | 0d |  |
| 199 |  | Fab LISST pump assy | 5d | 2003-01-15 | 2003-01-21 | 198 | 3d |  |
| 200 |  | Assy LISST pump into vehicle | 2d | 2003-01-22 | 2003-01-23 | 199 | 3d |  |
| 201 |  | Design LISST mount | 5d | 2003-01-15 | 2003-01-21 | 198 | 0d |  |
| 202 |  | Fab LISST Mount | 5d | 2003-01-22 | 2003-01-28 | 201 | 0d |  |
| 203 |  | Assy LISST mount | 2d | 2003-01-29 | 2003-01-30 | 200, 202 | 0d |  |
| 204 |  | Cable LISST to Dcon | 1d | 2003-01-31 | 2003-01-31 | 203 | 4d |  |
| 205 |  | Write Test Driver for LISST | 5d | 2003-01-31 | 2003-02-06 | 203 | 0d |  |
| 206 |  | Design Bathypho mount | 4d | 2003-01-09 | 2003-01-14 |  | 6d |  |
| 207 |  | Fab Bathypho mount | 5d | 2003-01-15 | 2003-01-21 | 206 | 6d |  |
| 208 |  | Assy Bathypho mount | 2d | 2003-01-22 | 2003-01-23 | 207 | 6d |  |
| 209 |  | Cable Bathypho to Dcon | 1d | 2003-01-24 | 2003-01-24 | 208 | 6d |  |
| 210 |  | Retest driver for Bathypho (already written) | 3d | 2003-01-27 | 2003-01-29 | 209 | 6d |  |
| 212 |  | Ryan / Haddock Cruise Prep | 14d | 2002-08-15 | 2002-09-03 |  | 112d | start no earlier than 2002-08-15 |

## Version 2 (saved 2002-05-13, file Dorado2002revC.mpp)

Last finish 2003-02-06 → 2002-11-19 (-79d). Complete tasks 2 → 16.

Changed:

| ID | Task | Start | Finish | Duration | Complete | Total float | Predecessors | Other |
| --- | --- | --- | --- | --- | --- | --- | --- | --- |
| 1 | **Dorado Program** |  | 2003-02-06 → 2002-11-19 (-79d) | 235d? → 178d? | 0% → 8% |  |  |  |
| 3 | **Propulsion** | 2002-03-15 → 2002-05-02 A (+48d) | 2002-09-09 → 2002-09-17 (+8d) | 127d → 99d | 0% → 1% | 51d → 45d |  |  |
| 4 | **Articulated Tail** | 2002-03-15 → 2002-05-02 (+48d) | 2002-03-28 → 2002-09-11 (+167d) | 10d → 95d |  | 164d → 45d |  |  |
| 5 | Design & Build New Electronics Housing | 2002-03-15 → 2002-05-02 (+48d) | 2002-03-28 → 2002-05-15 (+48d) |  |  | 164d → 130d |  | constraint none → start no earlier than 2002-05-02 |
| 6 | New Linear Actuator Scheme | 2002-03-15 → 2002-09-03 (+172d) | 2002-03-25 → 2002-09-11 (+170d) |  |  | 167d → 45d |  | constraint none → start no earlier than 2002-09-03 |
| 7 | **Drive Electronics** | 2002-03-15 → 2002-05-06 (+52d) | 2002-04-17 → 2002-06-06 (+50d) |  |  | 148d → 113d |  |  |
| 8 | Integrate New Electroincs | 2002-03-15 → 2002-05-06 (+52d) | 2002-04-17 → 2002-06-06 (+50d) |  |  | 148d → 112d |  | constraint start no earlier than 2002-03-15 → start no earlier than 2002-05-05 |
| 9 | Cabling | 2002-03-28 → 2002-05-27 (+60d) | 2002-04-03 → 2002-05-31 (+58d) |  |  | 158d → 116d |  | constraint start no earlier than 2002-03-28 → start no earlier than 2002-05-27 |
| 10 | Integrate New Tail Into fairing | 2002-04-18 → 2002-06-07 (+50d) | 2002-04-24 → 2002-06-13 (+50d) |  |  | 148d → 112d |  |  |
| 11 | Tailcone - Bench Stand Design and Fab | 2002-03-15 → 2002-05-27 (+73d) | 2002-03-19 → 2002-05-29 (+71d) |  |  | 175d → 124d |  | constraint none → start no earlier than 2002-05-27 |
| 12 | Buoyancy Check / Test | 2002-04-25 → 2002-06-14 A (+50d) | 2002-04-25 → 2002-06-14 A (+50d) |  | 0% → 100% | 148d → none |  |  |
| 13 | Test Plan | 2002-04-08 → 2002-06-14 (+67d) | 2002-04-12 → 2002-06-20 (+69d) |  |  | 157d → 108d |  | constraint start no earlier than 2002-04-08 → start no earlier than 2002-06-14 |
| 14 | **Tailcone Documetation** | 2002-04-18 → 2002-09-12 (+147d) | 2002-09-09 → 2002-09-17 (+8d) | 103d → 4d |  | 51d → 45d |  |  |
| 15 | Mechanical | 2002-04-18 → 2002-09-12 (+147d) | 2002-04-22 → 2002-09-16 (+147d) |  |  | 151d → 46d |  |  |
| 16 | Electrical | 2002-09-02 → 2002-09-12 (+10d) | 2002-09-03 → 2002-09-13 (+10d) |  |  | 55d → 47d |  |  |
| 17 | Software | 2002-09-04 → 2002-09-12 (+8d) | 2002-09-09 → 2002-09-17 (+8d) |  |  | 51d → 45d |  |  |
| 19 | **Power** | 2002-03-15 → 2002-04-15 A (+31d) | 2002-05-22 → 2002-06-24 (+33d) | 49d? → 51d? | 0% → 9% | 139d → 163d |  |  |
| 20 | **Battery Chemistry** | 2002-03-15 → 2002-04-15 A (+31d) | 2002-04-22 → 2002-05-23 (+31d) | 27d → 29d | 0% → 15% | 139d → 182d |  |  |
| 21 | Check life on current Ag-Zn batteries | 2002-03-15 → 2002-04-15 A (+31d) | 2002-03-18 → 2002-04-18 (+31d) | 2d → 4d | 0% → 66% | 142d → 119d |  | constraint none → start no earlier than 2002-04-13 |
| 22 | Trade study to review Batt Chems | 2002-03-15 → 2002-04-18 A (+34d) | 2002-03-18 → 2002-04-22 (+35d) | 2d → 3d | 0% → 80% | 142d → 117d |  | constraint none → start no earlier than 2002-04-18 |
| 23 | Thermal Analysis of Battery Pack | 2002-03-15 → 2002-04-17 (+33d) | 2002-03-21 → 2002-04-23 (+33d) |  |  | 139d → 116d |  | constraint none → start no earlier than 2002-04-17 |
| 24 | Design Review of Batt Chems | 2002-03-22 → 2002-04-24 (+33d) | 2002-03-22 → 2002-04-24 (+33d) |  |  | 139d → 116d |  |  |
| 25 | Purchase Batteries | 2002-03-25 → 2002-04-25 (+31d) | 2002-03-25 → 2002-04-25 (+31d) |  |  | 205d → 182d |  |  |
| 26 | Assemble Batteries | 2002-03-26 → 2002-04-26 (+31d) | 2002-04-01 → 2002-05-02 (+31d) |  |  | 205d → 182d |  |  |
| 27 | Test Batteries | 2002-04-02 → 2002-05-03 (+31d) | 2002-04-22 → 2002-05-23 (+31d) |  |  | 205d → 182d |  |  |
| 28 | **Battery Housing** | 2002-03-25 → 2002-04-25 A (+31d) | 2002-05-03 → 2002-06-11 (+39d) | 30d → 34d | 0% → 12% | 199d → 172d |  |  |
| 29 | Design | 2002-03-25 → 2002-05-01 (+37d) | 2002-04-05 → 2002-05-14 (+39d) |  |  | 199d → 172d |  | constraint none → start no earlier than 2002-05-01 |
| 30 | Build | 2002-04-08 → 2002-05-15 (+37d) | 2002-04-26 → 2002-06-04 (+39d) |  |  | 199d → 172d |  |  |
| 31 | Test | 2002-04-29 → 2002-06-05 (+37d) | 2002-05-03 → 2002-06-11 (+39d) |  |  | 199d → 172d |  |  |
| 32 | Spec Interconnects | 2002-03-25 → 2002-04-25 A (+31d) | 2002-03-28 → 2002-04-30 A (+33d) |  | 0% → 100% | 202d → none |  | constraint finish no earlier than 2002-03-25 → start no earlier than 2002-03-28 |
| 33 | **Battery Electronics** | 2002-04-22 → 2002-05-01 (+9d) | 2002-05-20 → 2002-06-10 (+21d) | 21d? → 29d? |  | 186d → 171d |  |  |
| 34 | Concept Design | 2002-04-22 → 2002-05-01 (+9d) | 2002-04-26 → 2002-05-07 (+11d) |  |  | 186d → 179d |  |  |
| 35 | Design Review | 2002-04-29 → 2002-05-08 (+9d) | 2002-04-30 → 2002-05-09 (+9d) |  |  | 186d → 179d |  |  |
| 36 | Final Design | 2002-05-01 → 2002-05-10 (+9d) | 2002-05-15 → 2002-05-24 (+9d) |  |  | 186d → 179d |  |  |
| 37 | Build | 2002-05-16 → 2002-05-27 (+11d) | 2002-05-16 → 2002-05-27 (+11d) |  |  | 186d → 179d |  |  |
| 38 | Assemble | 2002-05-17 → 2002-05-28 (+11d) | 2002-05-17 → 2002-05-28 (+11d) |  |  | 186d → 179d |  |  |
| 39 | Test | 2002-05-20 → 2002-05-29 (+9d) | 2002-05-20 → 2002-05-29 (+9d) |  |  | 186d → 179d |  |  |
| 40 | Spec Misc Electronics (Contingency) | 2002-04-26 → 2002-06-10 (+45d) | 2002-04-26 → 2002-06-10 (+45d) |  |  | 202d → 171d |  | constraint start no earlier than 2002-04-26 → start no earlier than 2002-06-10 |
| 41 | **Battery Charging** | 2002-05-21 → 2002-06-11 (+21d) | 2002-05-22 → 2002-06-12 (+21d) |  |  | 186d → 171d |  |  |
| 42 | Spec Charging Analysis | 2002-05-21 → 2002-06-11 (+21d) | 2002-05-22 → 2002-06-12 (+21d) |  |  | 186d → 171d |  |  |
| 43 | Order Charging Equip as Required | 2002-05-21 → 2002-06-11 (+21d) | 2002-05-21 → 2002-06-11 (+21d) |  |  | 187d → 172d |  |  |
| 44 | AUV Power Systems Meeting | 2002-04-26 → 2002-06-19 (+54d) | 2002-04-30 → 2002-06-24 (+55d) | 3d → 4d |  | 202d → 163d |  | constraint start no earlier than 2002-04-26 → start no earlier than 2002-06-19 |
| 46 | **Cabling and Connectors** | 2002-03-25 → 2002-04-25 A (+31d) | 2002-04-25 → 2002-06-21 (+57d) | 24d → 42d | 0% → 41% | 148d → 107d |  |  |
| 47 | Spec Main Power / Comms Cable&Connectors/Penetrators | 2002-03-25 → 2002-04-25 A (+31d) | 2002-04-10 → 2002-05-13 (+33d) |  | 0% → 50% | 148d → 124.66d |  |  |
| 48 | Spec Charging Connector | 2002-04-11 → 2002-05-14 (+33d) | 2002-04-16 → 2002-05-17 (+31d) |  |  | 155d → 132d |  |  |
| 49 | Spec Tailcone Comms Cable&Connector/Penetrator | 2002-03-25 → 2002-04-25 A (+31d) | 2002-03-27 → 2002-04-29 (+33d) |  | 0% → 80% | 158d → 134.66d |  |  |
| 50 | Spec Science Instrument Connector | 2002-03-25 → 2002-04-25 A (+31d) | 2002-03-26 → 2002-04-26 A (+31d) |  | 0% → 100% | 156d → none |  | constraint none → start no earlier than 2002-04-24 |
| 51 | Spec DVL and parosci Connectors / Penetrator | 2002-03-27 → 2002-04-29 A (+33d) | 2002-03-27 → 2002-04-29 A (+33d) |  | 0% → 100% | 156d → none |  |  |
| 52 | Spec RF/Acoustic/Emer location Connect & Penetrators | 2002-03-28 → 2002-04-30 A (+33d) | 2002-03-28 → 2002-04-30 A (+33d) |  | 0% → 100% | 156d → none |  |  |
| 53 | Spec On/Off Connector/Penetrator | 2002-03-29 → 2002-05-01 A (+33d) | 2002-03-29 → 2002-05-01 A (+33d) |  | 0% → 100% | 156d → none |  |  |
| 54 | Test ability of 100 MB/s thrugh current ALTEX Cable | 2002-03-25 → 2002-05-21 A (+57d) | 2002-03-26 → 2002-05-22 A (+57d) |  | 0% → 100% | 170d → none |  | constraint none → start no earlier than 2002-05-21 |
| 55 | Order Connectors | 2002-04-11 → 2002-05-14 A (+33d) | 2002-04-11 → 2002-05-15 (+34d) | 1d → 2d | 0% → 33% | 148d → 124d |  |  |
| 56 | **Tail to MVC** | 2002-03-25 → 2002-05-09 (+45d) | 2002-03-25 → 2002-05-09 (+45d) |  |  | 161d → 128d |  |  |
| 57 | Section Interconnect | 2002-03-25 → 2002-05-09 (+45d) | 2002-03-25 → 2002-05-09 (+45d) |  |  | 161d → 128d |  | constraint none → start no earlier than 2002-05-09 |
| 58 | Documetation package on Connectors and Cabling | 2002-04-12 → 2002-06-10 (+59d) | 2002-04-25 → 2002-06-21 (+57d) |  |  | 148d → 107d |  | constraint none → start no earlier than 2002-06-10 |
| 60 | **Main Vehicle Computer** |  | 2002-05-08 → 2002-09-19 (+134d) | 39d → 135d | 3% → 33% | 139d → 43d |  |  |
| 61 | **Electronics** |  | 2002-04-24 → 2002-06-05 (+42d) | 29d → 59d | 4% → 45% | 149d → 119d |  |  |
| 63 | Order PC 104 Stack |  | 2002-03-19 A → 2002-05-07 (+49d) | 1d → 2d | 100% → 40% | none → 138.8d |  |  |
| 64 | Assemble PC 104 Stack | 2002-03-20 → 2002-05-07 (+48d) | 2002-03-21 → 2002-05-09 (+49d) |  |  | 173d → 138.8d |  |  |
| 65 | Develop latency test/budget for MVC | 2002-04-11 → 2002-05-13 (+32d) | 2002-04-16 → 2002-05-16 (+30d) |  |  | 155d → 133d |  | constraint finish no earlier than 2002-04-16 → start no earlier than 2002-05-11 |
| 66 | **Power Board** | 2002-03-25 → 2002-04-28 A (+34d) | 2002-04-24 → 2002-05-29 (+35d) |  | 0% → 50% | 139d → 114d |  |  |
| 67 | Specify | 2002-03-25 → 2002-04-28 A (+34d) | 2002-03-28 → 2002-05-02 A (+35d) |  | 0% → 100% | 139d → none |  | constraint none → start no earlier than 2002-05-06 |
| 68 | Design | 2002-03-29 → 2002-05-03 A (+35d) | 2002-04-18 → 2002-05-23 (+35d) |  | 0% → 50% | 139d → 114d |  |  |
| 69 | Order | 2002-04-19 → 2002-05-24 (+35d) | 2002-04-19 → 2002-05-24 (+35d) |  |  | 139d → 114d |  |  |
| 70 | Build | 2002-04-22 → 2002-05-27 (+35d) | 2002-04-23 → 2002-05-28 (+35d) |  |  | 139d → 114d |  |  |
| 71 | Test | 2002-04-24 → 2002-05-29 (+35d) | 2002-04-24 → 2002-05-29 (+35d) |  |  | 139d → 114d |  |  |
| 72 | **RF Modem** | 2002-03-15 A | 2002-03-22 → 2002-05-15 (+54d) | 6d → 44d | 0% → 71% | 172d → 134d |  |  |
| 73 | Evaluate Data-link vs Freewave | 2002-03-15 A | 2002-03-21 A |  | 0% → 100% | 172d → none |  |  |
| 74 | Purchase | 2002-03-22 → 2002-05-14 (+53d) | 2002-03-22 → 2002-05-15 (+54d) | 1d → 2d |  | 172d → 134d | 73 → none | constraint none → start no earlier than 2002-05-14 |
| 75 | **Acoustic Modem** | 2002-03-15 → 2002-05-17 (+63d) | 2002-03-18 → 2002-05-20 (+63d) |  |  | 166d → 121d |  |  |

| ID | Task | Start | Finish | Duration | Complete | Total float | Predecessors | Other |
| --- | --- | --- | --- | --- | --- | --- | --- | --- |
| 76 | Evaluate | 2002-03-15 → 2002-05-17 (+63d) | 2002-03-15 → 2002-05-17 (+63d) |  |  | 166d → 121d |  | constraint none → start no earlier than 2002-05-17 |
| 77 | Purchase | 2002-03-18 → 2002-05-20 (+63d) | 2002-03-18 → 2002-05-20 (+63d) |  |  | 166d → 121d |  |  |
| 78 | **GPS** | 2002-03-15 → 2002-05-16 (+62d) | 2002-04-04 → 2002-06-05 (+62d) |  |  | 153d → 109d |  |  |
| 79 | Evaluate GPS Position Fix Problem | 2002-03-15 → 2002-05-16 (+62d) | 2002-03-28 → 2002-05-29 (+62d) |  |  | 153d → 109d |  | constraint none → start no earlier than 2002-05-16 |
| 80 | Evaluate GPS Board & Antennae | 2002-03-29 → 2002-05-30 (+62d) | 2002-04-03 → 2002-06-04 (+62d) |  |  | 153d → 109d |  |  |
| 81 | Purchase GPS Board & Antennae | 2002-04-04 → 2002-06-05 (+62d) | 2002-04-04 → 2002-06-05 (+62d) |  |  | 153d → 109d |  |  |
| 82 | Eval and Purchase 10/100 Hub | 2002-03-20 A | 2002-03-25 A |  | 0% → 100% | 171d → none |  |  |
| 83 | Eval & Purchase AHRS | 2002-03-15 A | 2002-03-15 A |  | 0% → 100% | 177d → none |  |  |
| 84 | Eval and Purchase LBL Board Set | 2002-03-15 A | 2002-03-20 A |  | 0% → 100% | 174d → none |  |  |
| 85 | Spec and Purcahse DVL | 2002-03-15 → 2002-05-14 A (+60d) | 2002-03-21 → 2002-05-20 (+60d) |  | 0% → 80% | 173d → 131d |  |  |
| 86 | **MVC Housing** | 2002-03-15 A | 2002-04-23 → 2002-06-04 (+42d) | 28d → 58d | 0% → 17% | 140d → 110d |  |  |
| 87 | Spec Interconnects | 2002-03-15 A |  |  | 0% → 80% |  |  |  |
| 88 | Design | 2002-03-25 → 2002-05-06 (+42d) | 2002-03-29 → 2002-05-10 (+42d) |  |  | 140d → 110d |  | constraint none → start no earlier than 2002-05-04 |
| 89 | Build/Purchase | 2002-04-01 → 2002-05-13 (+42d) | 2002-04-12 → 2002-05-24 (+42d) |  |  | 140d → 110d |  |  |
| 90 | Pressure Test | 2002-04-15 → 2002-05-27 (+42d) | 2002-04-16 → 2002-05-28 (+42d) |  |  | 140d → 110d |  |  |
| 91 | Electronics Packagin Layout | 2002-04-17 → 2002-05-29 (+42d) | 2002-04-23 → 2002-06-04 (+42d) |  |  | 140d → 110d |  |  |
| 92 | **Documentation Package** | 2002-04-25 → 2002-09-05 (+133d) | 2002-05-08 → 2002-09-19 (+134d) | 10d → 11d |  | 139d → 43d |  |  |
| 93 | Mechanical | 2002-04-25 → 2002-09-05 (+133d) | 2002-04-26 → 2002-09-06 (+133d) |  |  | 145d → 50d |  | constraint none → start no earlier than 2002-09-05 |
| 94 | Electrical | 2002-04-25 → 2002-09-05 (+133d) | 2002-05-06 → 2002-09-16 (+133d) |  |  | 139d → 44d |  | constraint none → start no earlier than 2002-09-05 |
| 95 | Software | 2002-04-25 → 2002-09-16 (+144d) | 2002-04-26 → 2002-09-17 (+144d) |  |  | 145d → 43d |  | constraint none → start no earlier than 2002-09-16 |
| 96 | Integration | 2002-05-07 → 2002-09-18 (+134d) | 2002-05-08 → 2002-09-19 (+134d) |  |  | 139d → 43d |  | constraint none → start no earlier than 2002-07-25 |
| 98 | **Navigation Hardware & Testing** | 2002-03-15 → 2002-09-02 A (+171d) | 2002-05-28 → 2002-11-13 (+169d) |  | 0% → 2% | 125d → 4d |  |  |
| 99 | **Deep Water testing of USBL** | 2002-03-15 → 2002-09-02 (+171d) | 2002-05-07 → 2002-10-23 (+169d) |  |  | 125d → 4d |  |  |
| 100 | Tank testing | 2002-03-15 → 2002-09-02 (+171d) | 2002-04-09 → 2002-09-25 (+169d) |  |  | 125d → 4d |  | constraint none → start no earlier than 2002-09-01 |
| 101 | At Sea Testing | 2002-04-10 → 2002-09-26 (+169d) | 2002-05-07 → 2002-10-23 (+169d) |  |  | 125d → 4d |  |  |
| 102 | **Deep Water Testing of LBL Fish Mode** | 2002-05-08 → 2002-10-24 (+169d) | 2002-05-28 → 2002-11-13 (+169d) |  |  | 125d → 4d |  |  |
| 103 | Tank Testing | 2002-05-08 → 2002-10-24 (+169d) | 2002-05-21 → 2002-11-06 (+169d) |  |  | 125d → 4d |  | constraint none → start no earlier than 2002-09-09 |
| 104 | At Sea Testing | 2002-05-22 → 2002-11-07 (+169d) | 2002-05-28 → 2002-11-13 (+169d) |  |  | 125d → 4d |  |  |
| 105 | Radio Range for modems | 2002-03-15 → 2002-09-06 (+175d) | 2002-03-19 → 2002-09-10 (+175d) |  |  | 175d → 50d |  | constraint none → start no earlier than 2002-09-06 |
| 106 | RDF Ranging | 2002-03-15 → 2002-09-09 (+178d) | 2002-03-19 → 2002-09-11 (+176d) |  |  | 174d → 48d |  | constraint none → start no earlier than 2002-09-07 |
| 107 | Eval Zephyr RDF capability | 2002-03-20 → 2002-09-12 A (+176d) | 2002-03-20 → 2002-09-12 A (+176d) |  | 0% → 100% | 174d → none |  |  |
| 109 | **Fairings / Vehicle Mechanical Structure** | 2002-03-15 A | 2002-05-27 → 2002-07-05 (+39d) | 52d → 81d | 0% → 5% | 126d → 97d |  |  |
| 110 | **L&R System Interface** | 2002-03-15 A | 2002-05-03 → 2002-07-05 (+63d) | 36d → 81d | 0% → 18% | 142d → 97d |  |  |
| 111 | Prelim Concept w/ Brook ocean | 2002-03-15 A | 2002-03-21 A |  | 0% → 100% | 142d → none |  |  |
| 112 | Concept Design Review / Decision | 2002-03-22 A | 2002-03-22 → 2002-05-24 (+63d) | 1d → 5.5d | 0% → 9% | 142d → 127d |  |  |
| 113 | Design L&R Interface | 2002-03-25 → 2002-05-27 (+63d) | 2002-04-05 → 2002-06-07 (+63d) |  |  | 142d → 97d | 112 → none | constraint none → start no earlier than 2002-05-27 |
| 114 | Build Interface | 2002-04-08 → 2002-06-10 (+63d) | 2002-04-19 → 2002-06-21 (+63d) |  |  | 142d → 97d |  |  |
| 115 | Assemble Interface | 2002-04-22 → 2002-06-24 (+63d) | 2002-04-26 → 2002-06-28 (+63d) |  |  | 142d → 97d |  |  |
| 116 | L&R test plan | 2002-03-15 → 2002-05-27 (+73d) | 2002-03-20 → 2002-05-30 (+71d) |  |  | 169d → 118d |  | constraint none → start no earlier than 2002-05-26 |
| 117 | Integrate and Test L&R Interface | 2002-04-29 → 2002-07-01 (+63d) | 2002-05-03 → 2002-07-05 (+63d) |  |  | 142d → 97d |  |  |
| 118 | Evaluate Single Point lift | 2002-03-26 → 2002-05-06 A (+41d) | 2002-03-28 → 2002-05-08 A (+41d) |  | 0% → 100% | 168d → none |  | constraint start no earlier than 2002-03-26 → start no earlier than 2002-05-04 |
| 119 | **Joining Ring/Systems** | 2002-03-15 → 2002-05-10 (+56d) | 2002-05-01 → 2002-07-01 (+61d) | 34d → 37d |  | 126d → 101d |  |  |
| 120 | Evaluate joining ring systems | 2002-03-15 → 2002-05-10 (+56d) | 2002-03-18 → 2002-05-13 (+56d) |  |  | 126d → 86d |  | constraint none → start no earlier than 2002-05-10 |
| 121 | Review Concept | 2002-03-19 → 2002-05-14 (+56d) | 2002-03-19 → 2002-05-14 (+56d) |  |  | 126d → 86d |  |  |
| 122 | Final Design | 2002-03-20 → 2002-05-15 (+56d) | 2002-04-09 → 2002-06-04 (+56d) |  |  | 126d → 86d |  |  |
| 123 | Build | 2002-04-10 → 2002-06-05 (+56d) | 2002-04-23 → 2002-06-18 (+56d) |  |  | 126d → 86d |  |  |
| 124 | Assemble | 2002-04-24 → 2002-06-19 (+56d) | 2002-04-26 → 2002-06-21 (+56d) |  |  | 126d → 86d |  |  |
| 125 | Test | 2002-04-29 → 2002-06-24 (+56d) | 2002-05-01 → 2002-06-26 (+56d) |  |  | 126d → 86d |  |  |
| 126 | Test new joining ring system | 2002-04-04 → 2002-06-27 (+84d) | 2002-04-08 → 2002-07-01 (+84d) |  |  | 143d → 83d |  | constraint start no earlier than 2002-04-04 → start no earlier than 2002-06-27 |
| 127 | **Deck Handling Equipment** | 2002-05-14 → 2002-05-20 (+6d) | 2002-05-27 → 2002-06-07 (+11d) | 10d → 15d |  | 126d → 117d | 141 → none |  |
| 128 | New Cart Design | 2002-05-14 → 2002-05-20 (+6d) | 2002-05-20 → 2002-05-24 (+4d) |  |  | 131d → 127d |  | constraint none → start no earlier than 2002-05-19 |
| 129 | New Lifitng Gear | 2002-05-14 → 2002-05-27 (+13d) | 2002-05-20 → 2002-05-31 (+11d) |  |  | 131d → 122d |  | constraint none → start no earlier than 2002-05-25 |
| 130 | Sphere Lift Mechanism | 2002-05-14 → 2002-05-21 (+7d) | 2002-05-27 → 2002-06-03 (+7d) |  |  | 126d → 121d |  | constraint none → start no earlier than 2002-05-21 |
| 131 | Eval Single Pt. Lift | 2002-05-14 → 2002-05-23 (+9d) | 2002-05-15 → 2002-05-24 (+9d) |  |  | 134d → 127d |  | constraint none → start no earlier than 2002-05-23 |
| 132 | Lifting I beam in Lab | 2002-05-14 → 2002-05-30 (+16d) | 2002-05-20 → 2002-06-05 (+16d) |  |  | 131d → 119d |  | constraint none → start no earlier than 2002-05-30 |
| 133 | Cable trays nad outlets in lab ceiling | 2002-05-14 → 2002-06-03 (+20d) | 2002-05-20 → 2002-06-07 (+18d) |  |  | 131d → 117d |  | constraint none → start no earlier than 2002-06-03 |
| 134 | **Sensor & Payload Mounts** | 2002-03-15 → 2002-05-20 (+66d) | 2002-03-20 → 2002-05-28 (+69d) | 4d → 7d |  | 156d → 117d |  |  |
| 135 | Antennaes | 2002-03-15 → 2002-05-20 (+66d) | 2002-03-20 → 2002-05-24 (+65d) | 4d → 5d |  | 156d → 109d |  | constraint none → start no earlier than 2002-05-18 |
| 136 | ORE & various equip | 2002-03-15 → 2002-05-23 (+69d) | 2002-03-20 → 2002-05-28 (+69d) |  |  | 156d → 107d |  | constraint none → start no earlier than 2002-05-23 |
| 137 | **Buoyancy** | 2002-03-15 → 2002-05-22 (+68d) | 2002-03-28 → 2002-06-04 (+68d) |  |  | 150d → 112d |  |  |
| 138 | Tailcone Foam Pack Specification | 2002-03-15 → 2002-05-22 (+68d) | 2002-03-21 → 2002-05-28 (+68d) |  |  | 150d → 102d |  | constraint none → start no earlier than 2002-05-22 |
| 139 | Tailcone foam machining | 2002-03-22 → 2002-05-29 (+68d) | 2002-03-28 → 2002-06-04 (+68d) |  |  | 150d → 102d |  |  |
| 140 | Modular trim / ballast systems concept | 2002-03-15 → 2002-05-22 (+68d) | 2002-03-21 → 2002-05-28 (+68d) |  |  | 155d → 107d |  | constraint none → start no earlier than 2002-05-22 |
| 141 | **Fairing Build** | 2002-05-02 → 2002-06-10 (+39d) | 2002-05-13 → 2002-06-26 (+44d) | 8d → 13d |  | 126d → 104d | 134, 137, 119 → 134, 137 |  |
| 142 | Noes section (2 plus 1 spare) | 2002-05-02 → 2002-06-10 (+39d) | 2002-05-13 → 2002-06-19 (+37d) |  |  | 126d → 109d |  | constraint none → start no earlier than 2002-06-10 |
| 143 | Midboady (2 plus 1 spare) | 2002-05-02 → 2002-06-13 (+42d) | 2002-05-13 → 2002-06-24 (+42d) |  |  | 126d → 106d |  | constraint none → start no earlier than 2002-06-13 |
| 144 | Tail section (2 plus 1 spare) | 2002-05-02 → 2002-06-17 (+46d) | 2002-05-13 → 2002-06-26 (+44d) |  |  | 126d → 104d |  | constraint none → start no earlier than 2002-06-17 |
| 146 | **Software** | 2002-03-15 → 2002-06-24 (+101d) |  | 178d → 107d |  |  |  |  |
| 149 | **OS Upgrade** | 2002-03-15 → 2002-09-12 (+181d) | 2002-03-22 → 2002-09-19 (+181d) |  |  | 172d → 43d |  |  |
| 150 | QNX Upgrade to Neutrino | 2002-03-15 → 2002-09-12 (+181d) | 2002-03-19 → 2002-09-16 (+181d) |  |  | 172d → 43d |  | constraint none → start no earlier than 2002-09-12 |

| ID | Task | Start | Finish | Duration | Total float | Predecessors | Other |
| --- | --- | --- | --- | --- | --- | --- | --- |
| 151 | Eval Linux for possible upgrade in future | 2002-03-20 → 2002-09-17 (+181d) | 2002-03-22 → 2002-09-19 (+181d) |  | 172d → 43d |  |  |
| 152 | **GUI** | 2002-03-15 → 2002-07-02 (+109d) | 2002-05-23 → 2002-09-09 (+109d) |  | 128d → 51d |  |  |
| 153 | gather requirements | 2002-03-15 → 2002-07-02 (+109d) | 2002-03-21 → 2002-07-08 (+109d) |  | 128d → 51d |  | constraint none → start no earlier than 2002-07-02 |
| 154 | eval Bluefin GUI | 2002-03-22 → 2002-07-09 (+109d) | 2002-04-04 → 2002-07-22 (+109d) |  | 128d → 51d |  |  |
| 155 | develop GUI plan | 2002-04-05 → 2002-07-23 (+109d) | 2002-04-11 → 2002-07-29 (+109d) |  | 128d → 51d |  |  |
| 156 | Detail GUI development (TBD) | 2002-04-12 → 2002-07-30 (+109d) | 2002-05-23 → 2002-09-09 (+109d) |  | 128d → 51d |  |  |
| 157 | Configuration management on vehicle (config files) | 2002-03-15 → 2002-08-16 (+154d) | 2002-04-04 → 2002-09-05 (+154d) |  | 163d → 53d |  | constraint none → start no earlier than 2002-08-16 |
| 158 | **Controls** | 2002-03-15 → 2002-06-24 (+101d) | 2002-05-16 → 2002-08-23 (+99d) |  | 133d → 62d |  |  |
| 159 | depth control improvement (long configs) | 2002-03-15 → 2002-06-24 (+101d) | 2002-04-04 → 2002-07-12 (+99d) |  | 133d → 62d |  | constraint none → start no earlier than 2002-06-22 |
| 160 | sway / yaw control coupling (heave/ pitch too) | 2002-04-05 → 2002-07-15 (+101d) | 2002-04-18 → 2002-07-26 (+99d) |  | 133d → 62d |  |  |
| 161 | slow speed dynamics for control | 2002-04-19 → 2002-07-29 (+101d) | 2002-05-16 → 2002-08-23 (+99d) |  | 133d → 62d |  |  |
| 172 | **Vehicle Integration and Test** | 2002-11-20 → 2002-06-10 (-163d) | 2003-01-07 → 2002-08-02 (-158d) | 35d → 40d | 0d → 76d | 3, 46, 109, 60, 98, 146 → none |  |
| 173 | Tailcone Assembly | 2002-11-20 → 2002-06-10 (-163d) | 2002-11-26 → 2002-06-14 (-165d) |  | 5d → 86d |  | constraint none → start no earlier than 2002-06-08 |
| 174 | Tailcone Test | 2002-11-27 → 2002-06-17 (-163d) | 2002-12-02 → 2002-06-20 (-165d) |  | 5d → 86d |  |  |
| 175 | Battery Midbody Integration | 2002-11-20 → 2002-06-17 (-156d) | 2002-11-26 → 2002-06-21 (-158d) |  | 5d → 81d |  | constraint none → start no earlier than 2002-06-17 |
| 176 | Battery Midbody Test | 2002-11-27 → 2002-06-24 (-156d) | 2002-12-02 → 2002-06-27 (-158d) |  | 5d → 81d |  |  |
| 177 | ALTEX Nose Payload Assembly/Upgrade | 2002-11-20 → 2002-06-17 (-156d) | 2002-11-26 → 2002-06-21 (-158d) |  | 0d → 76d |  | constraint none → start no earlier than 2002-06-17 |
| 178 | Science Payload Assembly | 2002-11-27 → 2002-06-24 (-156d) | 2002-12-04 → 2002-07-01 (-156d) |  | 0d → 76d |  |  |
| 179 | Payload Test | 2002-12-05 → 2002-07-02 (-156d) | 2002-12-09 → 2002-07-04 (-158d) |  | 0d → 76d |  |  |
| 180 | Integrated Vehcile Deck Assembly | 2002-12-10 → 2002-07-05 (-158d) | 2002-12-11 → 2002-07-08 (-156d) |  | 0d → 76d |  |  |
| 181 | Vehicle Ballasting | 2002-12-12 → 2002-07-09 (-156d) | 2002-12-12 → 2002-07-09 (-156d) |  | 0d → 76d |  |  |
| 182 | Integrated Vehicle Deck Test | 2002-12-13 → 2002-07-10 (-156d) | 2002-12-17 → 2002-07-12 (-158d) |  | 0d → 76d |  |  |
| 183 | Integrated Vehicle Tank Test | 2002-12-18 → 2002-07-15 (-156d) | 2002-12-24 → 2002-07-19 (-158d) |  | 0d → 76d |  |  |
| 184 | Integrated Vehicle Sea Trials | 2002-12-25 → 2002-07-22 (-156d) | 2003-01-07 → 2002-08-02 (-158d) |  | 0d → 76d |  |  |
| 186 | **CTD Science Payload Core** | 2002-03-15 → 2002-06-20 (+97d) | 2003-01-08 → 2002-08-05 (-156d) | 214d? → 33d? | 21d → 76d |  |  |
| 187 | Repair/Replace nose fairing | 2002-03-15 → 2002-06-20 (+97d) | 2002-03-19 → 2002-06-24 (+97d) |  | 175d → 157d |  | constraint none → start no earlier than 2002-06-20 |
| 188 | recable Dcon to comms and pwr bus | 2002-03-15 → 2002-06-21 (+98d) | 2002-03-26 → 2002-07-02 (+98d) |  | 151d → 132d |  | constraint none → start no earlier than 2002-06-21 |
| 189 | Design HS2 Mount | 2002-03-20 → 2002-06-25 (+97d) | 2002-03-21 → 2002-06-26 (+97d) |  | 175d → 157d |  |  |
| 190 | Build HS2 Mount | 2002-03-22 → 2002-06-27 (+97d) | 2002-03-25 → 2002-06-28 (+95d) |  | 175d → 157d |  |  |
| 191 | Assembly HS2 Mount | 2002-03-26 → 2002-07-01 (+97d) | 2002-03-27 → 2002-07-02 (+97d) |  | 175d → 157d |  |  |
| 192 | Write test driver HS2 | 2002-03-15 → 2002-06-27 (+104d) | 2002-03-21 → 2002-07-03 (+104d) |  | 179d → 156d |  | constraint none → start no earlier than 2002-06-27 |
| 193 | Eval Foam buoyancy cooridnate 1500 M version | 2002-03-15 → 2002-06-28 (+105d) | 2002-03-21 → 2002-07-04 (+105d) |  | 179d → 155d |  | constraint none → start no earlier than 2002-06-28 |
| 194 | repair flow sensor #2 | 2002-03-27 → 2002-07-03 (+98d) | 2002-03-29 → 2002-07-05 (+98d) |  | 151d → 132d |  |  |
| 195 | test integrated CTD Payload | 2003-01-08 → 2002-08-05 (-156d) | 2003-01-08 → 2002-08-05 (-156d) |  | 0d → 76d |  |  |
| 197 | **CTD Extension for Ryan/Haddock** | 2003-01-09 → 2002-06-03 (-220d) | 2003-02-06 → 2002-07-01 (-220d) |  | 0d → 101d | 194, 146, 195 → none |  |
| 198 | Design LISST pump assy | 2003-01-09 → 2002-06-03 (-220d) | 2003-01-14 → 2002-06-06 (-222d) |  | 0d → 101d |  | constraint none → start no earlier than 2002-06-03 |
| 199 | Fab LISST pump assy | 2003-01-15 → 2002-06-07 (-222d) | 2003-01-21 → 2002-06-13 (-222d) |  | 3d → 104d |  |  |
| 200 | Assy LISST pump into vehicle | 2003-01-22 → 2002-06-14 (-222d) | 2003-01-23 → 2002-06-17 (-220d) |  | 3d → 104d |  |  |
| 201 | Design LISST mount | 2003-01-15 → 2002-06-07 (-222d) | 2003-01-21 → 2002-06-13 (-222d) |  | 0d → 101d |  |  |
| 202 | Fab LISST Mount | 2003-01-22 → 2002-06-14 (-222d) | 2003-01-28 → 2002-06-20 (-222d) |  | 0d → 101d |  |  |
| 203 | Assy LISST mount | 2003-01-29 → 2002-06-21 (-222d) | 2003-01-30 → 2002-06-24 (-220d) |  | 0d → 101d |  |  |
| 204 | Cable LISST to Dcon | 2003-01-31 → 2002-06-25 (-220d) | 2003-01-31 → 2002-06-25 (-220d) |  | 4d → 105d |  |  |
| 205 | Write Test Driver for LISST | 2003-01-31 → 2002-06-25 (-220d) | 2003-02-06 → 2002-07-01 (-220d) |  | 0d → 101d |  |  |
| 206 | Design Bathypho mount | 2003-01-09 → 2002-06-05 (-218d) | 2003-01-14 → 2002-06-10 (-218d) |  | 6d → 105d |  | constraint none → start no earlier than 2002-06-05 |
| 207 | Fab Bathypho mount | 2003-01-15 → 2002-06-11 (-218d) | 2003-01-21 → 2002-06-17 (-218d) |  | 6d → 105d |  |  |
| 208 | Assy Bathypho mount | 2003-01-22 → 2002-06-18 (-218d) | 2003-01-23 → 2002-06-19 (-218d) |  | 6d → 105d |  |  |
| 209 | Cable Bathypho to Dcon | 2003-01-24 → 2002-06-20 (-218d) | 2003-01-24 → 2002-06-20 (-218d) |  | 6d → 105d |  |  |
| 210 | Retest driver for Bathypho (already written) | 2003-01-27 → 2002-06-21 (-220d) | 2003-01-29 → 2002-06-25 (-218d) |  | 6d → 105d |  |  |
| 212 | Ryan / Haddock Cruise Prep | 2002-08-15 → 2002-07-29 (-17d) | 2002-09-03 → 2002-08-15 (-19d) |  | 112d → 68d |  | constraint start no earlier than 2002-08-15 → start no earlier than 2002-07-27 |

## Version 3 (saved 2002-05-13, file Dorado2002revD.mpp)

Last finish stays 2002-11-19.

Changed:

| ID | Task | Total float | Other |
| --- | --- | --- | --- |
| 1 | **Dorado Program** |  | baseline start none → 2002-03-15; baseline finish none → 2002-11-19 |
| 3 | **Propulsion** |  | baseline start none → 2002-05-02; baseline finish none → 2002-09-17 |
| 4 | **Articulated Tail** |  | baseline start none → 2002-05-02; baseline finish none → 2002-09-11 |
| 5 | Design & Build New Electronics Housing |  | baseline start none → 2002-05-02; baseline finish none → 2002-05-15 |
| 6 | New Linear Actuator Scheme |  | baseline start none → 2002-09-03; baseline finish none → 2002-09-11 |
| 7 | **Drive Electronics** |  | baseline start none → 2002-05-06; baseline finish none → 2002-06-06 |
| 8 | Integrate New Electroincs | 112d → 113d | baseline start none → 2002-05-06; baseline finish none → 2002-06-06 |
| 9 | Cabling | 116d → 117d | baseline start none → 2002-05-27; baseline finish none → 2002-05-31 |
| 10 | Integrate New Tail Into fairing | 112d → 113d | baseline start none → 2002-06-07; baseline finish none → 2002-06-13 |
| 11 | Tailcone - Bench Stand Design and Fab |  | baseline start none → 2002-05-27; baseline finish none → 2002-05-29 |
| 12 | Buoyancy Check / Test |  | baseline start none → 2002-06-14; baseline finish none → 2002-06-14 |
| 13 | Test Plan |  | baseline start none → 2002-06-14; baseline finish none → 2002-06-20 |
| 14 | **Tailcone Documetation** |  | baseline start none → 2002-09-12; baseline finish none → 2002-09-17 |
| 15 | Mechanical |  | baseline start none → 2002-09-12; baseline finish none → 2002-09-16 |
| 16 | Electrical |  | baseline start none → 2002-09-12; baseline finish none → 2002-09-13 |
| 17 | Software |  | baseline start none → 2002-09-12; baseline finish none → 2002-09-17 |
| 19 | **Power** | 163d → 106d | baseline start none → 2002-04-15; baseline finish none → 2002-06-24 |
| 20 | **Battery Chemistry** | 182d → 125d | baseline start none → 2002-04-15; baseline finish none → 2002-05-23 |
| 21 | Check life on current Ag-Zn batteries | 119d → 122d | baseline start none → 2002-04-15; baseline finish none → 2002-04-18 |
| 22 | Trade study to review Batt Chems | 117d → 120d | baseline start none → 2002-04-18; baseline finish none → 2002-04-22 |
| 23 | Thermal Analysis of Battery Pack | 116d → 119d | baseline start none → 2002-04-17; baseline finish none → 2002-04-23 |
| 24 | Design Review of Batt Chems | 116d → 119d | baseline start none → 2002-04-24; baseline finish none → 2002-04-24 |
| 25 | Purchase Batteries | 182d → 125d | baseline start none → 2002-04-25; baseline finish none → 2002-04-25 |
| 26 | Assemble Batteries | 182d → 125d | baseline start none → 2002-04-26; baseline finish none → 2002-05-02 |
| 27 | Test Batteries | 182d → 125d | baseline start none → 2002-05-03; baseline finish none → 2002-05-23 |
| 28 | **Battery Housing** | 172d → 115d | baseline start none → 2002-04-25; baseline finish none → 2002-06-11 |
| 29 | Design | 172d → 115d | baseline start none → 2002-05-01; baseline finish none → 2002-05-14 |
| 30 | Build | 172d → 115d | baseline start none → 2002-05-15; baseline finish none → 2002-06-04 |
| 31 | Test | 172d → 115d | baseline start none → 2002-06-05; baseline finish none → 2002-06-11 |
| 32 | Spec Interconnects |  | baseline start none → 2002-04-25; baseline finish none → 2002-04-30 |
| 33 | **Battery Electronics** | 171d → 114d | baseline start none → 2002-05-01; baseline finish none → 2002-06-10 |
| 34 | Concept Design | 179d → 122d | baseline start none → 2002-05-01; baseline finish none → 2002-05-07 |
| 35 | Design Review | 179d → 122d | baseline start none → 2002-05-08; baseline finish none → 2002-05-09 |
| 36 | Final Design | 179d → 122d | baseline start none → 2002-05-10; baseline finish none → 2002-05-24 |
| 37 | Build | 179d → 122d | baseline start none → 2002-05-27; baseline finish none → 2002-05-27 |
| 38 | Assemble | 179d → 122d | baseline start none → 2002-05-28; baseline finish none → 2002-05-28 |
| 39 | Test | 179d → 122d | baseline start none → 2002-05-29; baseline finish none → 2002-05-29 |
| 40 | Spec Misc Electronics (Contingency) | 171d → 114d | baseline start none → 2002-06-10; baseline finish none → 2002-06-10 |
| 41 | **Battery Charging** | 171d → 114d | baseline start none → 2002-06-11; baseline finish none → 2002-06-12 |
| 42 | Spec Charging Analysis | 171d → 114d | baseline start none → 2002-06-11; baseline finish none → 2002-06-12 |
| 43 | Order Charging Equip as Required | 172d → 115d | baseline start none → 2002-06-11; baseline finish none → 2002-06-11 |
| 44 | AUV Power Systems Meeting | 163d → 106d | baseline start none → 2002-06-19; baseline finish none → 2002-06-24 |
| 46 | **Cabling and Connectors** |  | baseline start none → 2002-04-25; baseline finish none → 2002-06-21 |
| 47 | Spec Main Power / Comms Cable&Connectors/Penetrators |  | baseline start none → 2002-04-25; baseline finish none → 2002-05-13 |
| 48 | Spec Charging Connector |  | baseline start none → 2002-05-14; baseline finish none → 2002-05-17 |
| 49 | Spec Tailcone Comms Cable&Connector/Penetrator |  | baseline start none → 2002-04-25; baseline finish none → 2002-04-29 |
| 50 | Spec Science Instrument Connector |  | baseline start none → 2002-04-25; baseline finish none → 2002-04-26 |
| 51 | Spec DVL and parosci Connectors / Penetrator |  | baseline start none → 2002-04-29; baseline finish none → 2002-04-29 |
| 52 | Spec RF/Acoustic/Emer location Connect & Penetrators |  | baseline start none → 2002-04-30; baseline finish none → 2002-04-30 |
| 53 | Spec On/Off Connector/Penetrator |  | baseline start none → 2002-05-01; baseline finish none → 2002-05-01 |
| 54 | Test ability of 100 MB/s thrugh current ALTEX Cable |  | baseline start none → 2002-05-21; baseline finish none → 2002-05-22 |
| 55 | Order Connectors |  | baseline start none → 2002-05-14; baseline finish none → 2002-05-15 |
| 56 | **Tail to MVC** |  | baseline start none → 2002-05-09; baseline finish none → 2002-05-09 |
| 57 | Section Interconnect |  | baseline start none → 2002-05-09; baseline finish none → 2002-05-09 |
| 58 | Documetation package on Connectors and Cabling |  | baseline start none → 2002-06-10; baseline finish none → 2002-06-21 |
| 60 | **Main Vehicle Computer** |  | baseline start none → 2002-03-15; baseline finish none → 2002-09-19 |
| 61 | **Electronics** |  | baseline start none → 2002-03-15; baseline finish none → 2002-06-05 |
| 62 | Spec PC 104 Stack |  | baseline start none → 2002-03-15; baseline finish none → 2002-03-18 |
| 63 | Order PC 104 Stack |  | baseline start none → 2002-03-19; baseline finish none → 2002-05-07 |
| 64 | Assemble PC 104 Stack |  | baseline start none → 2002-05-07; baseline finish none → 2002-05-09 |
| 65 | Develop latency test/budget for MVC |  | baseline start none → 2002-05-13; baseline finish none → 2002-05-16 |
| 66 | **Power Board** |  | baseline start none → 2002-04-28; baseline finish none → 2002-05-29 |
| 67 | Specify |  | baseline start none → 2002-04-28; baseline finish none → 2002-05-02 |
| 68 | Design |  | baseline start none → 2002-05-03; baseline finish none → 2002-05-23 |
| 69 | Order |  | baseline start none → 2002-05-24; baseline finish none → 2002-05-24 |
| 70 | Build |  | baseline start none → 2002-05-27; baseline finish none → 2002-05-28 |
| 71 | Test |  | baseline start none → 2002-05-29; baseline finish none → 2002-05-29 |
| 72 | **RF Modem** |  | baseline start none → 2002-03-15; baseline finish none → 2002-05-15 |
| 73 | Evaluate Data-link vs Freewave |  | baseline start none → 2002-03-15; baseline finish none → 2002-03-21 |
| 74 | Purchase |  | baseline start none → 2002-05-14; baseline finish none → 2002-05-15 |

| ID | Task | Total float | Other |
| --- | --- | --- | --- |
| 75 | **Acoustic Modem** |  | baseline start none → 2002-05-17; baseline finish none → 2002-05-20 |
| 76 | Evaluate |  | baseline start none → 2002-05-17; baseline finish none → 2002-05-17 |
| 77 | Purchase |  | baseline start none → 2002-05-20; baseline finish none → 2002-05-20 |
| 78 | **GPS** |  | baseline start none → 2002-05-16; baseline finish none → 2002-06-05 |
| 79 | Evaluate GPS Position Fix Problem |  | baseline start none → 2002-05-16; baseline finish none → 2002-05-29 |
| 80 | Evaluate GPS Board & Antennae |  | baseline start none → 2002-05-30; baseline finish none → 2002-06-04 |
| 81 | Purchase GPS Board & Antennae |  | baseline start none → 2002-06-05; baseline finish none → 2002-06-05 |
| 82 | Eval and Purchase 10/100 Hub |  | baseline start none → 2002-03-20; baseline finish none → 2002-03-25 |
| 83 | Eval & Purchase AHRS |  | baseline start none → 2002-03-15; baseline finish none → 2002-03-15 |
| 84 | Eval and Purchase LBL Board Set |  | baseline start none → 2002-03-15; baseline finish none → 2002-03-20 |
| 85 | Spec and Purcahse DVL |  | baseline start none → 2002-05-14; baseline finish none → 2002-05-20 |
| 86 | **MVC Housing** |  | baseline start none → 2002-03-15; baseline finish none → 2002-06-04 |
| 87 | Spec Interconnects |  | baseline start none → 2002-03-15; baseline finish none → 2002-03-22 |
| 88 | Design |  | baseline start none → 2002-05-06; baseline finish none → 2002-05-10 |
| 89 | Build/Purchase |  | baseline start none → 2002-05-13; baseline finish none → 2002-05-24 |
| 90 | Pressure Test |  | baseline start none → 2002-05-27; baseline finish none → 2002-05-28 |
| 91 | Electronics Packagin Layout |  | baseline start none → 2002-05-29; baseline finish none → 2002-06-04 |
| 92 | **Documentation Package** |  | baseline start none → 2002-09-05; baseline finish none → 2002-09-19 |
| 93 | Mechanical |  | baseline start none → 2002-09-05; baseline finish none → 2002-09-06 |
| 94 | Electrical |  | baseline start none → 2002-09-05; baseline finish none → 2002-09-16 |
| 95 | Software |  | baseline start none → 2002-09-16; baseline finish none → 2002-09-17 |
| 96 | Integration |  | baseline start none → 2002-09-18; baseline finish none → 2002-09-19 |
| 98 | **Navigation Hardware & Testing** |  | baseline start none → 2002-09-02; baseline finish none → 2002-11-13 |
| 99 | **Deep Water testing of USBL** |  | baseline start none → 2002-09-02; baseline finish none → 2002-10-23 |
| 100 | Tank testing |  | baseline start none → 2002-09-02; baseline finish none → 2002-09-25 |
| 101 | At Sea Testing |  | baseline start none → 2002-09-26; baseline finish none → 2002-10-23 |
| 102 | **Deep Water Testing of LBL Fish Mode** |  | baseline start none → 2002-10-24; baseline finish none → 2002-11-13 |
| 103 | Tank Testing |  | baseline start none → 2002-10-24; baseline finish none → 2002-11-06 |
| 104 | At Sea Testing |  | baseline start none → 2002-11-07; baseline finish none → 2002-11-13 |
| 105 | Radio Range for modems |  | baseline start none → 2002-09-06; baseline finish none → 2002-09-10 |
| 106 | RDF Ranging | 48d → 49d | baseline start none → 2002-09-09; baseline finish none → 2002-09-11 |
| 107 | Eval Zephyr RDF capability |  | baseline start none → 2002-09-12; baseline finish none → 2002-09-12 |
| 109 | **Fairings / Vehicle Mechanical Structure** |  | baseline start none → 2002-03-15; baseline finish none → 2002-07-05 |
| 110 | **L&R System Interface** |  | baseline start none → 2002-03-15; baseline finish none → 2002-07-05 |
| 111 | Prelim Concept w/ Brook ocean |  | baseline start none → 2002-03-15; baseline finish none → 2002-03-21 |
| 112 | Concept Design Review / Decision |  | baseline start none → 2002-03-22; baseline finish none → 2002-05-24 |
| 113 | Design L&R Interface |  | baseline start none → 2002-05-27; baseline finish none → 2002-06-07 |
| 114 | Build Interface |  | baseline start none → 2002-06-10; baseline finish none → 2002-06-21 |
| 115 | Assemble Interface |  | baseline start none → 2002-06-24; baseline finish none → 2002-06-28 |
| 116 | L&R test plan |  | baseline start none → 2002-05-27; baseline finish none → 2002-05-30 |
| 117 | Integrate and Test L&R Interface |  | baseline start none → 2002-07-01; baseline finish none → 2002-07-05 |
| 118 | Evaluate Single Point lift |  | baseline start none → 2002-05-06; baseline finish none → 2002-05-08 |
| 119 | **Joining Ring/Systems** |  | baseline start none → 2002-05-10; baseline finish none → 2002-07-01 |
| 120 | Evaluate joining ring systems | 86d → 104d | baseline start none → 2002-05-10; baseline finish none → 2002-05-13 |
| 121 | Review Concept | 86d → 104d | baseline start none → 2002-05-14; baseline finish none → 2002-05-14 |
| 122 | Final Design | 86d → 104d | baseline start none → 2002-05-15; baseline finish none → 2002-06-04 |
| 123 | Build | 86d → 104d | baseline start none → 2002-06-05; baseline finish none → 2002-06-18 |
| 124 | Assemble | 86d → 104d | baseline start none → 2002-06-19; baseline finish none → 2002-06-21 |
| 125 | Test | 86d → 104d | baseline start none → 2002-06-24; baseline finish none → 2002-06-26 |
| 126 | Test new joining ring system | 83d → 101d | baseline start none → 2002-06-27; baseline finish none → 2002-07-01 |
| 127 | **Deck Handling Equipment** |  | baseline start none → 2002-05-20; baseline finish none → 2002-06-07 |
| 128 | New Cart Design |  | baseline start none → 2002-05-20; baseline finish none → 2002-05-24 |
| 129 | New Lifitng Gear |  | baseline start none → 2002-05-27; baseline finish none → 2002-05-31 |
| 130 | Sphere Lift Mechanism |  | baseline start none → 2002-05-21; baseline finish none → 2002-06-03 |
| 131 | Eval Single Pt. Lift |  | baseline start none → 2002-05-23; baseline finish none → 2002-05-24 |
| 132 | Lifting I beam in Lab |  | baseline start none → 2002-05-30; baseline finish none → 2002-06-05 |
| 133 | Cable trays nad outlets in lab ceiling |  | baseline start none → 2002-06-03; baseline finish none → 2002-06-07 |
| 134 | **Sensor & Payload Mounts** |  | baseline start none → 2002-05-20; baseline finish none → 2002-05-28 |
| 135 | Antennaes | 109d → 119d | baseline start none → 2002-05-20; baseline finish none → 2002-05-24 |
| 136 | ORE & various equip | 107d → 117d | baseline start none → 2002-05-23; baseline finish none → 2002-05-28 |
| 137 | **Buoyancy** |  | baseline start none → 2002-05-22; baseline finish none → 2002-06-04 |
| 138 | Tailcone Foam Pack Specification | 102d → 112d | baseline start none → 2002-05-22; baseline finish none → 2002-05-28 |
| 139 | Tailcone foam machining | 102d → 112d | baseline start none → 2002-05-29; baseline finish none → 2002-06-04 |
| 140 | Modular trim / ballast systems concept | 107d → 117d | baseline start none → 2002-05-22; baseline finish none → 2002-05-28 |
| 141 | **Fairing Build** |  | baseline start none → 2002-06-10; baseline finish none → 2002-06-26 |
| 142 | Noes section (2 plus 1 spare) |  | baseline start none → 2002-06-10; baseline finish none → 2002-06-19 |
| 143 | Midboady (2 plus 1 spare) |  | baseline start none → 2002-06-13; baseline finish none → 2002-06-24 |
| 144 | Tail section (2 plus 1 spare) |  | baseline start none → 2002-06-17; baseline finish none → 2002-06-26 |
| 146 | **Software** |  | baseline start none → 2002-06-24; baseline finish none → 2002-11-19 |
| 147 | Change supervisor so drivers run all the time |  | baseline start none → 2002-09-02; baseline finish none → 2002-09-04 |

| ID | Task | Total float | Other |
| --- | --- | --- | --- |
| 148 | Chang logging to convert files to MATLAB |  | baseline start none → 2002-09-05; baseline finish none → 2002-09-10 |
| 149 | **OS Upgrade** |  | baseline start none → 2002-09-12; baseline finish none → 2002-09-19 |
| 150 | QNX Upgrade to Neutrino |  | baseline start none → 2002-09-12; baseline finish none → 2002-09-16 |
| 151 | Eval Linux for possible upgrade in future |  | baseline start none → 2002-09-17; baseline finish none → 2002-09-19 |
| 152 | **GUI** |  | baseline start none → 2002-07-02; baseline finish none → 2002-09-09 |
| 153 | gather requirements |  | baseline start none → 2002-07-02; baseline finish none → 2002-07-08 |
| 154 | eval Bluefin GUI |  | baseline start none → 2002-07-09; baseline finish none → 2002-07-22 |
| 155 | develop GUI plan |  | baseline start none → 2002-07-23; baseline finish none → 2002-07-29 |
| 156 | Detail GUI development (TBD) |  | baseline start none → 2002-07-30; baseline finish none → 2002-09-09 |
| 157 | Configuration management on vehicle (config files) |  | baseline start none → 2002-08-16; baseline finish none → 2002-09-05 |
| 158 | **Controls** |  | baseline start none → 2002-06-24; baseline finish none → 2002-08-23 |
| 159 | depth control improvement (long configs) |  | baseline start none → 2002-06-24; baseline finish none → 2002-07-12 |
| 160 | sway / yaw control coupling (heave/ pitch too) |  | baseline start none → 2002-07-15; baseline finish none → 2002-07-26 |
| 161 | slow speed dynamics for control |  | baseline start none → 2002-07-29; baseline finish none → 2002-08-23 |
| 162 | **Navigation Software** |  | baseline start none → 2002-09-23; baseline finish none → 2002-11-19 |
| 163 | Document current NAV sys |  | baseline start none → 2002-09-23; baseline finish none → 2002-09-26 |
| 164 | Streamline current nav architecture |  | baseline start none → 2002-09-27; baseline finish none → 2002-10-08 |
| 165 | Single beacon homing |  | baseline start none → 2002-10-09; baseline finish none → 2002-10-29 |
| 166 | Single beacon LBL |  | baseline start none → 2002-10-30; baseline finish none → 2002-11-19 |
| 167 | DVL driver enhancements for PD5 |  | baseline start none → 2002-10-09; baseline finish none → 2002-10-29 |
| 168 | **Intra-vehicle Comms** |  | baseline start none → 2002-10-01; baseline finish none → 2002-10-04 |
| 169 | set up socket code (for reconnects) |  | baseline start none → 2002-10-01; baseline finish none → 2002-10-03 |
| 170 | briding over wireless |  | baseline start none → 2002-10-04; baseline finish none → 2002-10-04 |
| 172 | **Vehicle Integration and Test** |  | baseline start none → 2002-06-10; baseline finish none → 2002-08-02 |
| 173 | Tailcone Assembly |  | baseline start none → 2002-06-10; baseline finish none → 2002-06-14 |
| 174 | Tailcone Test |  | baseline start none → 2002-06-17; baseline finish none → 2002-06-20 |
| 175 | Battery Midbody Integration |  | baseline start none → 2002-06-17; baseline finish none → 2002-06-21 |
| 176 | Battery Midbody Test |  | baseline start none → 2002-06-24; baseline finish none → 2002-06-27 |
| 177 | ALTEX Nose Payload Assembly/Upgrade |  | baseline start none → 2002-06-17; baseline finish none → 2002-06-21 |
| 178 | Science Payload Assembly |  | baseline start none → 2002-06-24; baseline finish none → 2002-07-01 |
| 179 | Payload Test |  | baseline start none → 2002-07-02; baseline finish none → 2002-07-04 |
| 180 | Integrated Vehcile Deck Assembly |  | baseline start none → 2002-07-05; baseline finish none → 2002-07-08 |
| 181 | Vehicle Ballasting |  | baseline start none → 2002-07-09; baseline finish none → 2002-07-09 |
| 182 | Integrated Vehicle Deck Test |  | baseline start none → 2002-07-10; baseline finish none → 2002-07-12 |
| 183 | Integrated Vehicle Tank Test |  | baseline start none → 2002-07-15; baseline finish none → 2002-07-19 |
| 184 | Integrated Vehicle Sea Trials |  | baseline start none → 2002-07-22; baseline finish none → 2002-08-02 |
| 186 | **CTD Science Payload Core** |  | baseline start none → 2002-06-20; baseline finish none → 2002-08-05 |
| 187 | Repair/Replace nose fairing | 157d → 100d | baseline start none → 2002-06-20; baseline finish none → 2002-06-24 |
| 188 | recable Dcon to comms and pwr bus | 132d → 96d | baseline start none → 2002-06-21; baseline finish none → 2002-07-02 |
| 189 | Design HS2 Mount | 157d → 100d | baseline start none → 2002-06-25; baseline finish none → 2002-06-26 |
| 190 | Build HS2 Mount | 157d → 100d | baseline start none → 2002-06-27; baseline finish none → 2002-06-28 |
| 191 | Assembly HS2 Mount | 157d → 100d | baseline start none → 2002-07-01; baseline finish none → 2002-07-02 |
| 192 | Write test driver HS2 | 156d → 99d | baseline start none → 2002-06-27; baseline finish none → 2002-07-03 |
| 193 | Eval Foam buoyancy cooridnate 1500 M version | 155d → 98d | baseline start none → 2002-06-28; baseline finish none → 2002-07-04 |
| 194 | repair flow sensor #2 | 132d → 96d | baseline start none → 2002-07-03; baseline finish none → 2002-07-05 |
| 195 | test integrated CTD Payload |  | baseline start none → 2002-08-05; baseline finish none → 2002-08-05 |
| 197 | **CTD Extension for Ryan/Haddock** |  | baseline start none → 2002-06-03; baseline finish none → 2002-07-01 |
| 198 | Design LISST pump assy |  | baseline start none → 2002-06-03; baseline finish none → 2002-06-06 |
| 199 | Fab LISST pump assy |  | baseline start none → 2002-06-07; baseline finish none → 2002-06-13 |
| 200 | Assy LISST pump into vehicle |  | baseline start none → 2002-06-14; baseline finish none → 2002-06-17 |
| 201 | Design LISST mount |  | baseline start none → 2002-06-07; baseline finish none → 2002-06-13 |
| 202 | Fab LISST Mount |  | baseline start none → 2002-06-14; baseline finish none → 2002-06-20 |
| 203 | Assy LISST mount |  | baseline start none → 2002-06-21; baseline finish none → 2002-06-24 |
| 204 | Cable LISST to Dcon |  | baseline start none → 2002-06-25; baseline finish none → 2002-06-25 |
| 205 | Write Test Driver for LISST |  | baseline start none → 2002-06-25; baseline finish none → 2002-07-01 |
| 206 | Design Bathypho mount |  | baseline start none → 2002-06-05; baseline finish none → 2002-06-10 |
| 207 | Fab Bathypho mount |  | baseline start none → 2002-06-11; baseline finish none → 2002-06-17 |
| 208 | Assy Bathypho mount |  | baseline start none → 2002-06-18; baseline finish none → 2002-06-19 |
| 209 | Cable Bathypho to Dcon |  | baseline start none → 2002-06-20; baseline finish none → 2002-06-20 |
| 210 | Retest driver for Bathypho (already written) |  | baseline start none → 2002-06-21; baseline finish none → 2002-06-25 |
| 212 | Ryan / Haddock Cruise Prep |  | baseline start none → 2002-07-29; baseline finish none → 2002-08-15 |

## Version 4 (data date 2002-06-03, saved 2002-06-03, file Dorado2002revE.mpp)

Last finish stays 2002-11-19. Complete tasks 16 → 27.

Added:

| ID | Task | Duration | Start | Finish | Predecessors | Constraint | Resources |
| --- | --- | --- | --- | --- | --- | --- | --- |
| 14 | Replace foam with 4500 M | 20d | 2002-06-17 | 2002-07-12 |  | start no earlier than 2002-06-17 | Drew [15%] |
| 15 | Compensator Design/Purchase | 20d | 2002-06-10 | 2002-07-05 |  | start no earlier than 2002-06-10 | Robert F |
| 28 | Battery delivery | 40d? | 2002-06-14 | 2002-08-08 | 27 | start no earlier than 2002-06-14 |  |
| 62 | Cable Assy @ Seacon | 26d | 2002-06-18 | 2002-07-23 |  | start no earlier than 2002-06-18 | Seacon |

Changed:

| ID | Task | Start | Finish | Duration | Complete | Total float | Predecessors | Other |
| --- | --- | --- | --- | --- | --- | --- | --- | --- |
| 1 | **Dorado Program** |  |  |  | 8% → 15% |  |  |  |
| 3 | **Propulsion** | 2002-05-02 A → 2002-05-20 A (+18d) | 2002-09-17 → 2002-09-18 (+1d) | 99d → 88d | 1% → 10% | 45d → 44d |  |  |
| 4 | **Articulated Tail** | 2002-05-02 → 2002-05-20 A (+18d) |  | 95d → 83d | 0% → 38% | 45d → 44d |  |  |
| 5 | Design & Build New Electronics Housing | 2002-05-02 → 2002-05-20 A (+18d) | 2002-05-15 → 2002-06-19 (+35d) | 10d → 23d | 0% → 50% | 130d → 104d |  |  |
| 7 | **Drive Electronics** | 2002-05-06 → 2002-05-27 A (+21d) | 2002-06-06 → 2002-07-22 (+46d) | 24d → 41d |  | 113d → 81d |  |  |
| 8 | Integrate New Electroincs | 2002-05-06 → 2002-06-19 A (+44d) | 2002-06-06 → 2002-07-22 (+46d) |  |  | 113d → 81d |  |  |
| 10 | Integrate New Tail Into fairing | 2002-06-07 → 2002-07-23 (+46d) | 2002-06-13 → 2002-07-29 (+46d) |  |  | 113d → 81d |  |  |
| 16 | **Tailcone Documetation** |  | 2002-09-17 → 2002-09-18 (+1d) | 4d → 5d |  | 45d → 44d |  |  |
| 17 | Mechanical |  | 2002-09-16 → 2002-09-18 (+2d) | 3d → 5d |  | 46d → 44d |  | resources Farley → Farley; RobF |
| 21 | **Power** |  | 2002-06-24 → 2002-08-23 (+60d) | 51d? → 95d? | 9% → 10% | 106d → 62d |  |  |
| 22 | **Battery Chemistry** |  | 2002-05-23 → 2002-08-19 (+88d) | 29d → 91d? | 15% → 9% | 125d → 66d |  |  |
| 25 | Thermal Analysis of Battery Pack |  |  |  |  | 119d → 150d |  | resources Kiwi → Cancelled Task |
| 26 | Design Review of Batt Chems | 2002-04-24 → 2002-06-03 A (+40d) | 2002-04-24 → 2002-06-03 A (+40d) |  | 0% → 100% | 119d → none |  |  |
| 27 | Purchase Batteries | 2002-04-25 → 2002-06-04 (+40d) | 2002-04-25 → 2002-06-07 (+43d) | 1d → 4d |  | 125d → 66d |  |  |
| 29 | Assemble Batteries | 2002-04-26 → 2002-08-09 (+105d) | 2002-05-02 → 2002-08-14 (+104d) | 5d → 4d |  | 125d → 62d | 27 → 28 |  |
| 30 | Test Batteries | 2002-05-03 → 2002-08-15 (+104d) | 2002-05-23 → 2002-08-19 (+88d) | 15d → 3d |  | 125d → 62d |  |  |
| 31 | **Battery Housing** |  | 2002-06-11 → 2002-07-15 (+34d) | 34d → 58d |  | 115d → 91d |  |  |
| 32 | Design | 2002-05-01 → 2002-06-04 (+34d) | 2002-05-14 → 2002-06-17 (+34d) |  |  | 115d → 91d |  | resources Craig → On Hold |
| 33 | Build | 2002-05-15 → 2002-06-18 (+34d) | 2002-06-04 → 2002-07-08 (+34d) |  |  | 115d → 91d |  | resources ME TECH → On Hold |
| 34 | Test | 2002-06-05 → 2002-07-09 (+34d) | 2002-06-11 → 2002-07-15 (+34d) |  |  | 115d → 91d |  | resources Craig → On Hold |
| 36 | **Battery Electronics** | 2002-05-01 → 2002-06-04 A (+34d) | 2002-06-10 → 2002-08-23 (+74d) | 29d? → 59d? | 0% → 10% | 114d → 62d |  |  |
| 37 | Concept Design | 2002-05-01 → 2002-06-04 A (+34d) | 2002-05-07 → 2002-06-10 (+34d) |  | 0% → 50% | 122d → 100d |  |  |
| 38 | Design Review | 2002-05-08 → 2002-06-11 (+34d) | 2002-05-09 → 2002-06-12 (+34d) |  |  | 122d → 100d |  |  |
| 39 | Final Design | 2002-05-10 → 2002-06-13 (+34d) | 2002-05-24 → 2002-06-27 (+34d) |  |  | 122d → 100d |  |  |
| 40 | Build | 2002-05-27 → 2002-06-28 (+32d) | 2002-05-27 → 2002-06-28 (+32d) |  |  | 122d → 100d |  |  |
| 41 | Assemble | 2002-05-28 → 2002-07-01 (+34d) | 2002-05-28 → 2002-07-01 (+34d) |  |  | 122d → 100d |  |  |
| 42 | Test | 2002-05-29 → 2002-07-02 (+34d) | 2002-05-29 → 2002-07-02 (+34d) |  |  | 122d → 100d |  |  |
| 43 | Spec Misc Electronics (Contingency) | 2002-06-10 → 2002-08-20 (+71d) | 2002-06-10 → 2002-08-23 (+74d) | 1d? → 4d? |  | 114d → 62d |  |  |
| 44 | **Battery Charging** | 2002-06-11 → 2002-06-21 (+10d) | 2002-06-12 → 2002-06-26 (+14d) | 2d → 4d |  | 114d → 104d | 26, 36 → 26 |  |
| 45 | Spec Charging Analysis | 2002-06-11 → 2002-06-21 (+10d) | 2002-06-12 → 2002-06-24 (+12d) |  |  | 114d → 106d |  | constraint none → start no earlier than 2002-06-21 |
| 46 | Order Charging Equip as Required | 2002-06-11 → 2002-06-24 (+13d) | 2002-06-11 → 2002-06-26 (+15d) | 1d → 3d |  | 115d → 104d |  | constraint none → start no earlier than 2002-06-22 |
| 49 | **Cabling and Connectors** |  | 2002-06-21 → 2002-07-23 (+32d) | 42d → 64d | 41% → 44% | 107d → 85d |  |  |
| 50 | Spec Main Power / Comms Cable&Connectors/Penetrators |  | 2002-05-13 → 2002-06-12 A (+30d) |  | 50% → 100% | 124.66d → none |  |  |
| 51 | Spec Charging Connector | 2002-05-14 → 2002-06-12 A (+29d) | 2002-05-17 → 2002-06-18 (+32d) |  | 0% → 50% | 132d → 110.5d |  |  |
| 52 | Spec Tailcone Comms Cable&Connector/Penetrator |  | 2002-04-29 → 2002-06-05 A (+37d) | 3d → 4.4d | 80% → 100% | 134.66d → none |  |  |
| 58 | Order Connectors |  | 2002-05-15 → 2002-05-20 A (+5d) | 2d → 5d | 33% → 100% | 124d → none |  |  |
| 59 | **Tail to MVC** | 2002-05-09 → 2002-06-04 A (+26d) | 2002-05-09 → 2002-06-07 (+29d) | 1d → 4d | 0% → 30% | 128d → 107d |  |  |
| 60 | Section Interconnect | 2002-05-09 → 2002-06-04 A (+26d) | 2002-05-09 → 2002-06-07 (+29d) | 1d → 4d | 0% → 30% | 128d → 107d |  |  |
| 61 | Documetation package on Connectors and Cabling | 2002-06-10 → 2002-06-13 (+3d) | 2002-06-21 → 2002-06-26 (+5d) |  |  | 107d → 104d |  | constraint start no earlier than 2002-06-10 → start no earlier than 2002-06-13 |
| 64 | **Main Vehicle Computer** |  | 2002-09-19 → 2002-10-04 (+15d) | 135d → 146d | 33% → 44% | 43d → 32d |  |  |
| 65 | **Electronics** |  | 2002-06-05 → 2002-09-20 (+107d) | 59d → 136d | 45% → 60% | 119d → 42d |  |  |
| 67 | Order PC 104 Stack |  | 2002-05-07 A |  | 40% → 100% | 138.8d → none |  |  |
| 68 | Assemble PC 104 Stack | 2002-05-07 A | 2002-05-09 A |  | 0% → 100% | 138.8d → none |  |  |
| 69 | Develop latency test/budget for MVC | 2002-05-13 → 2002-05-27 A (+14d) | 2002-05-16 → 2002-06-07 (+22d) | 4d → 10d | 0% → 50% | 133d → 117d |  |  |
| 70 | **Power Board** |  | 2002-05-29 → 2002-06-19 (+21d) | 23d → 37.5d | 50% → 87% | 114d → 99.5d |  |  |
| 72 | Design |  | 2002-05-23 → 2002-06-13 A (+21d) |  | 50% → 100% | 114d → none |  |  |
| 73 | Order | 2002-05-24 → 2002-06-13 A (+20d) | 2002-05-24 → 2002-06-14 A (+21d) |  | 0% → 100% | 114d → none |  |  |
| 74 | Build | 2002-05-27 → 2002-06-14 (+18d) | 2002-05-28 → 2002-06-18 (+21d) |  |  | 114d → 99.5d |  |  |
| 75 | Test | 2002-05-29 → 2002-06-18 (+20d) | 2002-05-29 → 2002-06-19 (+21d) |  |  | 114d → 99.5d |  |  |
| 79 | **Acoustic Modem** | 2002-05-17 → 2002-09-16 A (+122d) | 2002-05-20 → 2002-09-20 (+123d) | 2d → 5d |  | 121d → 32d |  |  |
| 80 | Evaluate | 2002-05-17 → 2002-09-16 A (+122d) | 2002-05-17 → 2002-09-17 (+123d) | 1d → 2d |  | 121d → 32d |  |  |
| 81 | Purchase | 2002-05-20 → 2002-09-18 (+121d) | 2002-05-20 → 2002-09-20 (+123d) | 1d → 3d |  | 121d → 32d |  |  |
| 82 | **GPS** | 2002-05-16 → 2002-06-10 A (+25d) | 2002-06-05 → 2002-06-28 (+23d) |  |  | 109d → 92d |  |  |
| 83 | Evaluate GPS Position Fix Problem | 2002-05-16 → 2002-06-10 A (+25d) | 2002-05-29 → 2002-06-21 (+23d) |  |  | 109d → 92d |  |  |
| 84 | Evaluate GPS Board & Antennae | 2002-05-30 → 2002-06-24 (+25d) | 2002-06-04 → 2002-06-27 (+23d) |  |  | 109d → 92d |  |  |
| 85 | Purchase GPS Board & Antennae | 2002-06-05 → 2002-06-28 (+23d) | 2002-06-05 → 2002-06-28 (+23d) |  |  | 109d → 92d |  |  |
| 89 | Spec and Purcahse DVL |  | 2002-05-20 → 2002-08-09 (+81d) | 5d → 7d | 80% → 57% | 131d → 72d |  |  |
| 90 | **MVC Housing** |  | 2002-06-04 → 2002-07-09 (+35d) | 58d → 83d | 17% → 21% | 110d → 85d |  |  |
| 91 | Spec Interconnects |  | 2002-03-22 A |  | 80% → 100% | 140d → none |  |  |
| 92 | Design | 2002-05-06 → 2002-06-10 (+35d) | 2002-05-10 → 2002-06-14 (+35d) |  |  | 110d → 85d |  | constraint start no earlier than 2002-05-04 → start no earlier than 2002-06-09 |
| 93 | Build/Purchase | 2002-05-13 → 2002-06-17 (+35d) | 2002-05-24 → 2002-06-28 (+35d) |  |  | 110d → 85d |  |  |
| 94 | Pressure Test | 2002-05-27 → 2002-07-01 (+35d) | 2002-05-28 → 2002-07-02 (+35d) |  |  | 110d → 85d |  |  |
| 95 | Electronics Packagin Layout | 2002-05-29 → 2002-07-03 (+35d) | 2002-06-04 → 2002-07-09 (+35d) |  |  | 110d → 85d |  |  |
| 96 | **Documentation Package** | 2002-09-05 → 2002-09-23 (+18d) | 2002-09-19 → 2002-10-04 (+15d) | 11d → 10d |  | 43d → 32d |  |  |
| 97 | Mechanical | 2002-09-05 → 2002-09-23 (+18d) | 2002-09-06 → 2002-09-24 (+18d) |  |  | 50d → 38d |  |  |
| 98 | Electrical | 2002-09-05 → 2002-09-23 (+18d) | 2002-09-16 → 2002-10-02 (+16d) |  |  | 44d → 32d |  |  |
| 99 | Software | 2002-09-16 → 2002-09-23 (+7d) | 2002-09-17 → 2002-09-24 (+7d) |  |  | 43d → 38d |  |  |
| 100 | Integration | 2002-09-18 → 2002-10-03 (+15d) | 2002-09-19 → 2002-10-04 (+15d) |  |  | 43d → 32d |  |  |
| 113 | **Fairings / Vehicle Mechanical Structure** |  | 2002-07-05 → 2002-10-17 (+104d) | 81d → 155d | 5% → 14% | 97d → 23d |  |  |
| 114 | **L&R System Interface** |  | 2002-07-05 → 2002-08-02 (+28d) | 81d → 101d | 18% → 28% | 97d → 77d |  |  |

| ID | Task | Start | Finish | Duration | Complete | Total float | Other |
| --- | --- | --- | --- | --- | --- | --- | --- |
| 116 | Concept Design Review / Decision |  | 2002-05-24 A |  | 9% → 100% | 127d → none |  |
| 117 | Design L&R Interface | 2002-05-27 → 2002-06-24 (+28d) | 2002-06-07 → 2002-07-05 (+28d) |  |  | 97d → 77d | constraint start no earlier than 2002-05-27 → start no earlier than 2002-06-22 |
| 118 | Build Interface | 2002-06-10 → 2002-07-08 (+28d) | 2002-06-21 → 2002-07-19 (+28d) |  |  | 97d → 77d |  |
| 119 | Assemble Interface | 2002-06-24 → 2002-07-22 (+28d) | 2002-06-28 → 2002-07-26 (+28d) |  |  | 97d → 77d |  |
| 120 | L&R test plan | 2002-05-27 → 2002-06-24 (+28d) | 2002-05-30 → 2002-06-27 (+28d) |  |  | 118d → 98d | constraint start no earlier than 2002-05-26 → start no earlier than 2002-06-24 |
| 121 | Integrate and Test L&R Interface | 2002-07-01 → 2002-07-29 (+28d) | 2002-07-05 → 2002-08-02 (+28d) |  |  | 97d → 77d |  |
| 123 | **Joining Ring/Systems** | 2002-05-10 → 2002-09-02 (+115d) | 2002-07-01 → 2002-10-17 (+108d) | 37d → 34d |  | 101d → 23d |  |
| 124 | Evaluate joining ring systems | 2002-05-10 → 2002-09-02 (+115d) | 2002-05-13 → 2002-09-03 (+113d) |  |  | 104d → 23d | constraint start no earlier than 2002-05-10 → start no earlier than 2002-09-02 |
| 125 | Review Concept | 2002-05-14 → 2002-09-04 (+113d) | 2002-05-14 → 2002-09-04 (+113d) |  |  | 104d → 23d |  |
| 126 | Final Design | 2002-05-15 → 2002-09-05 (+113d) | 2002-06-04 → 2002-09-25 (+113d) |  |  | 104d → 23d |  |
| 127 | Build | 2002-06-05 → 2002-09-26 (+113d) | 2002-06-18 → 2002-10-09 (+113d) |  |  | 104d → 23d |  |
| 128 | Assemble | 2002-06-19 → 2002-10-10 (+113d) | 2002-06-21 → 2002-10-14 (+115d) |  |  | 104d → 23d |  |
| 129 | Test | 2002-06-24 → 2002-10-15 (+113d) | 2002-06-26 → 2002-10-17 (+113d) |  |  | 104d → 23d |  |
| 130 | Test new joining ring system | 2002-06-27 → 2002-09-17 (+82d) | 2002-07-01 → 2002-09-19 (+80d) |  |  | 101d → 43d | constraint start no earlier than 2002-06-27 → start no earlier than 2002-09-17 |
| 131 | **Deck Handling Equipment** | 2002-05-20 A | 2002-06-07 → 2002-09-18 (+103d) | 15d → 88d | 0% → 28% | 117d → 44d |  |
| 132 | New Cart Design | 2002-05-20 A | 2002-05-24 → 2002-07-05 (+42d) | 5d → 7d | 0% → 50% | 127d → 97d |  |
| 133 | New Lifitng Gear | 2002-05-27 A | 2002-05-31 → 2002-07-05 (+35d) | 5d → 7d | 0% → 30% | 122d → 97d |  |
| 134 | Sphere Lift Mechanism | 2002-05-21 → 2002-09-05 (+107d) | 2002-06-03 → 2002-09-18 (+107d) |  |  | 121d → 44d | constraint start no earlier than 2002-05-21 → start no earlier than 2002-09-05 |
| 135 | Eval Single Pt. Lift | 2002-05-23 A | 2002-05-24 A |  | 0% → 100% | 127d → none |  |
| 136 | Lifting I beam in Lab | 2002-05-30 A |  |  | 0% → 50% |  |  |
| 137 | Cable trays nad outlets in lab ceiling | 2002-06-03 → 2002-07-15 (+42d) | 2002-06-07 → 2002-07-19 (+42d) |  |  | 117d → 87d | constraint start no earlier than 2002-06-03 → start no earlier than 2002-07-14 |
| 138 | **Sensor & Payload Mounts** | 2002-05-20 → 2002-06-21 (+32d) | 2002-05-28 → 2002-06-27 (+30d) | 7d → 5d |  | 117d → 95d |  |
| 139 | Antennaes | 2002-05-20 → 2002-06-21 (+32d) | 2002-05-24 → 2002-06-27 (+34d) |  |  | 119d → 95d | constraint start no earlier than 2002-05-18 → start no earlier than 2002-06-21 |
| 140 | ORE & various equip | 2002-05-23 → 2002-06-24 (+32d) | 2002-05-28 → 2002-06-27 (+30d) |  |  | 117d → 95d | constraint start no earlier than 2002-05-23 → start no earlier than 2002-06-24 |
| 141 | **Buoyancy** | 2002-05-22 → 2002-06-13 (+22d) | 2002-06-04 → 2002-07-11 (+37d) | 10d → 21d |  | 112d → 85d |  |
| 142 | Tailcone Foam Pack Specification | 2002-05-22 → 2002-06-28 (+37d) | 2002-05-28 → 2002-07-04 (+37d) |  |  | 112d → 85d | constraint start no earlier than 2002-05-22 → start no earlier than 2002-06-28 |
| 143 | Tailcone foam machining | 2002-05-29 → 2002-07-05 (+37d) | 2002-06-04 → 2002-07-11 (+37d) |  |  | 112d → 85d |  |
| 144 | Modular trim / ballast systems concept | 2002-05-22 → 2002-06-13 (+22d) | 2002-05-28 → 2002-06-24 (+27d) | 5d → 8d |  | 117d → 98d | constraint start no earlier than 2002-05-22 → start no earlier than 2002-06-13 |
| 145 | **Fairing Build** | 2002-06-10 → 2002-07-12 (+32d) | 2002-06-26 → 2002-07-23 (+27d) | 13d → 8d |  | 104d → 85d |  |
| 146 | Noes section (2 plus 1 spare) | 2002-06-10 → 2002-07-12 (+32d) | 2002-06-19 → 2002-07-23 (+34d) |  |  | 109d → 85d |  |
| 147 | Midboady (2 plus 1 spare) | 2002-06-13 → 2002-07-12 (+29d) | 2002-06-24 → 2002-07-23 (+29d) |  |  | 106d → 85d |  |
| 148 | Tail section (2 plus 1 spare) | 2002-06-17 → 2002-07-12 (+25d) | 2002-06-26 → 2002-07-23 (+27d) |  |  | 104d → 85d |  |
| 150 | **Software** | 2002-06-24 → 2002-06-06 A (-18d) |  | 107d → 119d | 0% → 4% |  |  |
| 156 | **GUI** | 2002-07-02 → 2002-06-06 (-26d) | 2002-09-09 → 2002-08-14 (-26d) |  |  | 51d → 69d |  |
| 157 | gather requirements | 2002-07-02 → 2002-06-06 (-26d) | 2002-07-08 → 2002-06-12 (-26d) |  |  | 51d → 69d | constraint start no earlier than 2002-07-02 → start no earlier than 2002-06-06 |
| 158 | eval Bluefin GUI | 2002-07-09 → 2002-06-13 (-26d) | 2002-07-22 → 2002-06-26 (-26d) |  |  | 51d → 69d |  |
| 159 | develop GUI plan | 2002-07-23 → 2002-06-27 (-26d) | 2002-07-29 → 2002-07-03 (-26d) |  |  | 51d → 69d |  |
| 160 | Detail GUI development (TBD) | 2002-07-30 → 2002-07-04 (-26d) | 2002-09-09 → 2002-08-14 (-26d) |  |  | 51d → 69d |  |
| 161 | Configuration management on vehicle (config files) | 2002-08-16 → 2002-07-09 (-38d) | 2002-09-05 → 2002-07-29 (-38d) |  |  | 53d → 81d | constraint start no earlier than 2002-08-16 → start no earlier than 2002-07-09 |
| 162 | **Controls** | 2002-06-24 → 2002-07-19 (+25d) | 2002-08-23 → 2002-09-19 (+27d) |  |  | 62d → 43d |  |
| 163 | depth control improvement (long configs) | 2002-06-24 → 2002-07-19 (+25d) | 2002-07-12 → 2002-08-08 (+27d) |  |  | 62d → 43d | constraint start no earlier than 2002-06-22 → start no earlier than 2002-07-19 |
| 164 | sway / yaw control coupling (heave/ pitch too) | 2002-07-15 → 2002-08-09 (+25d) | 2002-07-26 → 2002-08-22 (+27d) |  |  | 62d → 43d |  |
| 165 | slow speed dynamics for control | 2002-07-29 → 2002-08-23 (+25d) | 2002-08-23 → 2002-09-19 (+27d) |  |  | 62d → 43d |  |
| 166 | **Navigation Software** | 2002-09-23 A |  |  | 0% → 13% |  |  |
| 171 | DVL driver enhancements for PD5 | 2002-10-09 A |  |  | 0% → 50% |  |  |
| 176 | **Vehicle Integration and Test** | 2002-06-10 → 2002-07-18 (+38d) | 2002-08-02 → 2002-09-04 (+33d) | 40d → 35d |  | 76d → 53d |  |
| 177 | Tailcone Assembly | 2002-06-10 → 2002-07-18 (+38d) | 2002-06-14 → 2002-07-24 (+40d) |  |  | 86d → 62d | constraint start no earlier than 2002-06-08 → start no earlier than 2002-07-18 |
| 178 | Tailcone Test | 2002-06-17 → 2002-07-25 (+38d) | 2002-06-20 → 2002-07-30 (+40d) |  |  | 86d → 62d |  |
| 179 | Battery Midbody Integration | 2002-06-17 → 2002-07-31 (+44d) | 2002-06-21 → 2002-08-06 (+46d) |  |  | 81d → 53d | constraint start no earlier than 2002-06-17 → start no earlier than 2002-07-31 |
| 180 | Battery Midbody Test | 2002-06-24 → 2002-08-07 (+44d) | 2002-06-27 → 2002-08-12 (+46d) |  |  | 81d → 53d |  |
| 181 | ALTEX Nose Payload Assembly/Upgrade | 2002-06-17 → 2002-07-19 (+32d) | 2002-06-21 → 2002-07-25 (+34d) |  |  | 76d → 56d | constraint start no earlier than 2002-06-17 → start no earlier than 2002-07-19 |
| 182 | Science Payload Assembly | 2002-06-24 → 2002-07-26 (+32d) | 2002-07-01 → 2002-08-02 (+32d) |  |  | 76d → 56d |  |
| 183 | Payload Test | 2002-07-02 → 2002-08-05 (+34d) | 2002-07-04 → 2002-08-07 (+34d) |  |  | 76d → 56d |  |
| 184 | Integrated Vehcile Deck Assembly | 2002-07-05 → 2002-08-13 (+39d) | 2002-07-08 → 2002-08-14 (+37d) |  |  | 76d → 53d |  |
| 185 | Vehicle Ballasting | 2002-07-09 → 2002-08-15 (+37d) | 2002-07-09 → 2002-08-15 (+37d) |  |  | 76d → 53d |  |
| 186 | Integrated Vehicle Deck Test | 2002-07-10 → 2002-08-16 (+37d) | 2002-07-12 → 2002-08-20 (+39d) |  |  | 76d → 53d |  |
| 187 | Integrated Vehicle Tank Test | 2002-07-15 → 2002-08-21 (+37d) | 2002-07-19 → 2002-08-27 (+39d) |  |  | 76d → 53d |  |
| 188 | Integrated Vehicle Sea Trials | 2002-07-22 → 2002-08-28 (+37d) | 2002-08-02 → 2002-09-04 (+33d) | 10d → 6d |  | 76d → 53d |  |
| 190 | **CTD Science Payload Core** | 2002-06-20 → 2002-06-27 A (+7d) | 2002-08-05 → 2002-09-05 (+31d) | 33d? → 51d? | 0% → 8% | 76d → 53d |  |
| 191 | Repair/Replace nose fairing | 2002-06-20 → 2002-07-22 (+32d) | 2002-06-24 → 2002-07-24 (+30d) |  |  | 100d → 78d | constraint start no earlier than 2002-06-20 → start no earlier than 2002-07-20 |
| 192 | recable Dcon to comms and pwr bus | 2002-06-21 → 2002-07-29 (+38d) | 2002-07-02 → 2002-08-07 (+36d) |  |  | 96d → 70d | constraint start no earlier than 2002-06-21 → start no earlier than 2002-07-27 |
| 193 | Design HS2 Mount | 2002-06-25 → 2002-07-25 (+30d) | 2002-06-26 → 2002-07-26 (+30d) |  |  | 100d → 78d |  |
| 194 | Build HS2 Mount | 2002-06-27 → 2002-07-29 (+32d) | 2002-06-28 → 2002-07-30 (+32d) |  |  | 100d → 78d |  |
| 195 | Assembly HS2 Mount | 2002-07-01 → 2002-07-31 (+30d) | 2002-07-02 → 2002-08-01 (+30d) |  |  | 100d → 78d |  |
| 196 | Write test driver HS2 | 2002-06-27 A |  |  | 0% → 50% |  |  |
| 198 | repair flow sensor #2 | 2002-07-03 → 2002-08-08 (+36d) | 2002-07-05 → 2002-08-12 (+38d) |  |  | 96d → 70d |  |
| 199 | test integrated CTD Payload | 2002-08-05 → 2002-09-05 (+31d) | 2002-08-05 → 2002-09-05 (+31d) |  |  | 76d → 53d |  |
| 201 | **CTD Extension for Ryan/Haddock** | 2002-06-03 → 2002-06-27 (+24d) | 2002-07-01 → 2002-07-25 (+24d) |  |  | 101d → 83d |  |
| 202 | Design LISST pump assy | 2002-06-03 → 2002-06-27 (+24d) | 2002-06-06 → 2002-07-02 (+26d) |  |  | 101d → 83d | constraint start no earlier than 2002-06-03 → start no earlier than 2002-06-27 |
| 203 | Fab LISST pump assy | 2002-06-07 → 2002-07-03 (+26d) | 2002-06-13 → 2002-07-09 (+26d) |  |  | 104d → 86d |  |

| ID | Task | Start | Finish | Total float | Other |
| --- | --- | --- | --- | --- | --- |
| 204 | Assy LISST pump into vehicle | 2002-06-14 → 2002-07-10 (+26d) | 2002-06-17 → 2002-07-11 (+24d) | 104d → 86d |  |
| 205 | Design LISST mount | 2002-06-07 → 2002-07-03 (+26d) | 2002-06-13 → 2002-07-09 (+26d) | 101d → 83d |  |
| 206 | Fab LISST Mount | 2002-06-14 → 2002-07-10 (+26d) | 2002-06-20 → 2002-07-16 (+26d) | 101d → 83d |  |
| 207 | Assy LISST mount | 2002-06-21 → 2002-07-17 (+26d) | 2002-06-24 → 2002-07-18 (+24d) | 101d → 83d |  |
| 208 | Cable LISST to Dcon | 2002-06-25 → 2002-07-19 (+24d) | 2002-06-25 → 2002-07-19 (+24d) | 105d → 87d |  |
| 209 | Write Test Driver for LISST | 2002-06-25 → 2002-07-19 (+24d) | 2002-07-01 → 2002-07-25 (+24d) | 101d → 83d |  |
| 210 | Design Bathypho mount | 2002-06-05 → 2002-07-03 (+28d) | 2002-06-10 → 2002-07-08 (+28d) | 105d → 85d | constraint start no earlier than 2002-06-05 → start no earlier than 2002-07-03 |
| 211 | Fab Bathypho mount | 2002-06-11 → 2002-07-09 (+28d) | 2002-06-17 → 2002-07-15 (+28d) | 105d → 85d |  |
| 212 | Assy Bathypho mount | 2002-06-18 → 2002-07-16 (+28d) | 2002-06-19 → 2002-07-17 (+28d) | 105d → 85d |  |
| 213 | Cable Bathypho to Dcon | 2002-06-20 → 2002-07-18 (+28d) | 2002-06-20 → 2002-07-18 (+28d) | 105d → 85d |  |
| 214 | Retest driver for Bathypho (already written) | 2002-06-21 → 2002-07-19 (+28d) | 2002-06-25 → 2002-07-23 (+28d) | 105d → 85d |  |
| 216 | Ryan / Haddock Cruise Prep | 2002-07-29 → 2002-08-05 (+7d) | 2002-08-15 → 2002-08-22 (+7d) | 68d → 63d | constraint start no earlier than 2002-07-27 → start no earlier than 2002-08-05 |

## Version 5 (data date 2002-06-03, saved 2002-06-06, file Dorado2002revF.mpp)

Last finish stays 2002-11-19.

Changed:

| ID | Task | Other |
| --- | --- | --- |
| 49 | **Cabling and Connectors** | resources Drew → none |
| 77 | Evaluate Data-link vs Freewave | resources Drew [50%] → Eric [50%] |
| 82 | **GPS** | resources Drew → Eric |
| 83 | Evaluate GPS Position Fix Problem | resources Craig → Eric |
| 84 | Evaluate GPS Board & Antennae | resources Craig → Eric |
| 85 | Purchase GPS Board & Antennae | resources Drew [25%] → Eric [25%] |
| 113 | **Fairings / Vehicle Mechanical Structure** | resources Drew → none |
| 114 | **L&R System Interface** | resources Drew → none |
| 131 | **Deck Handling Equipment** | resources Drew → none |
| 138 | **Sensor & Payload Mounts** | resources Drew → none |
| 141 | **Buoyancy** | resources Drew → none |
| 145 | **Fairing Build** | resources Drew → none |

## Version 6 (data date 2002-06-03, saved 2002-07-08, file Dorado2002revG.mpp)

Last finish stays 2002-11-19. Complete tasks 27 → 33.

Added:

| ID | Task | Duration | Start | Finish | Predecessors | Constraint | Resources |
| --- | --- | --- | --- | --- | --- | --- | --- |
| 40 | Potted Junction | 21d? | 2002-07-01 | 2002-07-29 |  | start no earlier than 2002-06-30 | Sib; Hans |
| 218 | JBOX and tether fix | 6d? | 2002-06-26 | 2002-07-03 |  | start no earlier than 2002-06-26 |  |
| 219 | External Parosci mounted | 6d? | 2002-06-26 | 2002-07-03 |  | start no earlier than 2002-06-26 |  |
| 220 | Dcon housing modifications | 13d? | 2002-06-26 | 2002-07-12 |  | start no earlier than 2002-06-26 |  |
| 221 | CTD nose section complete | 23d? | 2002-06-26 | 2002-07-26 |  | start no earlier than 2002-06-26 |  |
| 222 | Bathy and Lisst mounted | 23d? | 2002-06-26 | 2002-07-26 |  | start no earlier than 2002-06-26 |  |
| 223 | GPS Soltuion in place | 23d? | 2002-06-26 | 2002-07-26 |  | start no earlier than 2002-06-26 |  |
| 224 | New battery sphere | 25d? | 2002-07-01 | 2002-08-02 |  | start no earlier than 2002-07-01 |  |
| 225 | Three AgZn bats charged | 10d? | 2002-07-22 | 2002-08-02 |  | start no earlier than 2002-07-22 |  |
| 226 | Hardware freeze date | 1d? | 2002-08-02 | 2002-08-02 |  | start no earlier than 2002-08-02 |  |
| 227 | Vehicle buttoned up and ready | 2d? | 2002-08-01 | 2002-08-02 |  | start no earlier than 2002-08-01 |  |
| 228 | Mobilize Zephyr | 2d? | 2002-08-01 | 2002-08-02 |  | start no earlier than 2002-08-01 |  |
| 229 | Sea trials of vehicle | 5d? | 2002-08-05 | 2002-08-09 | 228, 227, 225 | start no earlier than 2002-08-05 |  |
| 230 | Tracking pole and sng pt lift | 25d? | 2002-07-15 | 2002-08-16 |  | start no earlier than 2002-07-15 |  |
| 231 | Mob of PT Sur | 2d? | 2002-08-16 | 2002-08-19 |  | start no earlier than 2002-08-16 |  |
| 232 | Off-board data analysis | 7d? | 2002-08-09 | 2002-08-19 |  | start no earlier than 2002-08-09 |  |
| 233 | Ocean complexity cruise | 6d? | 2002-08-20 | 2002-08-27 | 231, 230 | start no earlier than 2002-08-20 |  |
| 234 | Demob Pt Sur | 2d? | 2002-08-28 | 2002-08-29 | 233 | start no earlier than 2002-08-27 |  |

Changed:

| ID | Task | Start | Finish | Duration | Complete | Total float | Predecessors | Other |
| --- | --- | --- | --- | --- | --- | --- | --- | --- |
| 1 | **Dorado Program** |  |  |  | 15% → 16% |  |  |  |
| 3 | **Propulsion** |  |  |  | 10% → 14% |  |  | baseline start 2002-05-02 → 2002-05-20; baseline finish 2002-09-17 → 2002-09-18 |
| 4 | **Articulated Tail** |  |  |  |  |  |  | baseline start 2002-05-02 → 2002-05-20 |
| 5 | Design & Build New Electronics Housing |  | 2002-06-19 → 2002-07-18 (+29d) |  |  | 104d → 83.5d |  | resources Farley → Robert F; baseline start 2002-05-02 → 2002-05-20; baseline finish 2002-05-15 → 2002-07-18 |
| 7 | **Drive Electronics** | 2002-05-27 A → 2002-07-11 A (+45d) | 2002-07-22 → 2002-08-13 (+22d) | 41d → 24d |  | 81d → 65d |  | baseline start 2002-05-06 → 2002-07-11; baseline finish 2002-06-06 → 2002-08-13 |
| 8 | Integrate New Electroincs | 2002-06-19 A → 2002-07-11 A (+22d) | 2002-07-22 → 2002-08-13 (+22d) |  |  | 81d → 65d |  | baseline start 2002-05-06 → 2002-07-11; baseline finish 2002-06-06 → 2002-08-13 |
| 9 | Cabling | 2002-05-27 → 2002-08-01 (+66d) | 2002-05-31 → 2002-08-07 (+68d) |  |  | 117d → 69d |  | constraint start no earlier than 2002-05-27 → start no earlier than 2002-08-01; baseline start 2002-05-27 → 2002-08-01; baseline finish 2002-05-31 → 2002-08-07 |
| 10 | Integrate New Tail Into fairing | 2002-07-23 → 2002-08-14 (+22d) | 2002-07-29 → 2002-08-20 (+22d) |  |  | 81d → 65d |  | baseline start 2002-06-07 → 2002-08-14; baseline finish 2002-06-13 → 2002-08-20 |
| 11 | Tailcone - Bench Stand Design and Fab | 2002-05-27 → 2002-08-01 (+66d) | 2002-05-29 → 2002-08-05 (+68d) |  |  | 124d → 76d |  | constraint start no earlier than 2002-05-27 → start no earlier than 2002-08-01; baseline start 2002-05-27 → 2002-08-01; baseline finish 2002-05-29 → 2002-08-05 |
| 13 | Test Plan | 2002-06-14 → 2002-07-04 (+20d) | 2002-06-20 → 2002-07-10 (+20d) |  |  | 108d → 94d |  | constraint start no earlier than 2002-06-14 → start no earlier than 2002-07-04; baseline start 2002-06-14 → 2002-07-04; baseline finish 2002-06-20 → 2002-07-10 |
| 14 | Replace foam with 4500 M | 2002-06-17 A |  |  | 0% → 25% |  |  | constraint start no earlier than 2002-06-17 → start no earlier than 2002-06-16; baseline start none → 2002-06-17; baseline finish none → 2002-07-12 |
| 15 | Compensator Design/Purchase | 2002-06-10 → 2002-06-11 (+1d) | 2002-07-05 → 2002-07-08 (+3d) |  |  | 97d → 96d |  | constraint start no earlier than 2002-06-10 → start no earlier than 2002-06-11; baseline start none → 2002-06-11; baseline finish none → 2002-07-08 |
| 16 | **Tailcone Documetation** |  |  |  |  |  |  | baseline finish 2002-09-17 → 2002-09-18 |
| 17 | Mechanical |  |  |  |  |  |  | baseline finish 2002-09-16 → 2002-09-18 |
| 21 | **Power** |  | 2002-08-23 → 2002-09-11 (+19d) | 95d? → 108d? | 10% → 12% | 62d → 49d |  | baseline finish 2002-06-24 → 2002-09-11 |
| 22 | **Battery Chemistry** |  | 2002-08-19 → 2002-09-05 (+17d) | 91d? → 104d? |  | 66d → 53d |  | baseline finish 2002-05-23 → 2002-09-05 |
| 26 | Design Review of Batt Chems |  |  |  |  |  |  | baseline start 2002-04-24 → 2002-06-03; baseline finish 2002-04-24 → 2002-06-03 |
| 27 | Purchase Batteries | 2002-06-04 → 2002-06-27 (+23d) | 2002-06-07 → 2002-07-02 (+25d) |  |  | 66d → 49d |  | constraint none → start no earlier than 2002-06-27; baseline start 2002-04-25 → 2002-06-27; baseline finish 2002-04-25 → 2002-07-02 |
| 28 | Battery delivery | 2002-06-14 → 2002-07-03 (+19d) | 2002-08-08 → 2002-08-27 (+19d) |  |  | 62d → 49d |  | baseline start none → 2002-07-03; baseline finish none → 2002-08-27 |
| 29 | Assemble Batteries | 2002-08-09 → 2002-08-28 (+19d) | 2002-08-14 → 2002-09-02 (+19d) |  |  | 62d → 49d |  | baseline start 2002-04-26 → 2002-08-28; baseline finish 2002-05-02 → 2002-09-02 |
| 30 | Test Batteries | 2002-08-15 → 2002-09-03 (+19d) | 2002-08-19 → 2002-09-05 (+17d) |  |  | 62d → 49d |  | baseline start 2002-05-03 → 2002-09-03; baseline finish 2002-05-23 → 2002-09-05 |
| 31 | **Battery Housing** |  |  |  |  |  |  | baseline finish 2002-06-11 → 2002-07-15 |
| 32 | Design |  |  |  |  |  |  | baseline start 2002-05-01 → 2002-06-04; baseline finish 2002-05-14 → 2002-06-17 |
| 33 | Build |  |  |  |  |  |  | baseline start 2002-05-15 → 2002-06-18; baseline finish 2002-06-04 → 2002-07-08 |
| 34 | Test |  |  |  |  |  |  | baseline start 2002-06-05 → 2002-07-09; baseline finish 2002-06-11 → 2002-07-15 |
| 36 | **Battery Electronics** |  | 2002-08-23 → 2002-09-11 (+19d) | 59d? → 72d? | 10% → 6% | 62d → 49d |  | baseline start 2002-05-01 → 2002-06-04; baseline finish 2002-06-10 → 2002-09-11 |
| 37 | Concept Design |  | 2002-06-10 → 2002-06-07 (-3d) | 5d → 4d | 50% → 63% | 100d → 104d |  | resources Sib → On Hold; baseline start 2002-05-01 → 2002-06-04; baseline finish 2002-05-07 → 2002-06-07 |
| 38 | Design Review | 2002-06-11 → 2002-06-10 (-1d) | 2002-06-12 → 2002-06-11 (-1d) |  |  | 100d → 104d |  | resources Sib → On Hold; baseline start 2002-05-08 → 2002-06-10; baseline finish 2002-05-09 → 2002-06-11 |
| 39 | Final Design | 2002-06-13 → 2002-06-12 (-1d) | 2002-06-27 → 2002-06-26 (-1d) |  |  | 100d → 104d |  | resources Sib [75%] → On Hold [75%]; baseline start 2002-05-10 → 2002-06-12; baseline finish 2002-05-24 → 2002-06-26 |
| 41 | Build | 2002-06-28 → 2002-09-02 (+66d) | 2002-06-28 → 2002-09-02 (+66d) |  |  | 100d → 54d | 39 → 40 | constraint none → start no earlier than 2002-09-02; baseline start 2002-05-27 → 2002-09-02; baseline finish 2002-05-27 → 2002-09-02 |
| 42 | Assemble | 2002-07-01 → 2002-09-03 (+64d) | 2002-07-01 → 2002-09-03 (+64d) |  |  | 100d → 54d |  | baseline start 2002-05-28 → 2002-09-03; baseline finish 2002-05-28 → 2002-09-03 |
| 43 | Test | 2002-07-02 → 2002-09-04 (+64d) | 2002-07-02 → 2002-09-04 (+64d) |  |  | 100d → 54d |  | baseline start 2002-05-29 → 2002-09-04; baseline finish 2002-05-29 → 2002-09-04 |
| 44 | Spec Misc Electronics (Contingency) | 2002-08-20 → 2002-09-06 (+17d) | 2002-08-23 → 2002-09-11 (+19d) |  |  | 62d → 49d |  | baseline start 2002-06-10 → 2002-09-06; baseline finish 2002-06-10 → 2002-09-11 |
| 45 | **Battery Charging** | 2002-06-21 A | 2002-06-26 → 2002-07-25 (+29d) | 4d → 25d | 0% → 33% | 104d → 83d |  | baseline start 2002-06-11 → 2002-06-21; baseline finish 2002-06-12 → 2002-07-25 |
| 46 | Spec Charging Analysis | 2002-06-21 A | 2002-06-24 A |  | 0% → 100% | 106d → none |  | baseline start 2002-06-11 → 2002-06-21; baseline finish 2002-06-12 → 2002-06-24 |
| 47 | Order Charging Equip as Required | 2002-06-24 → 2002-07-22 (+28d) | 2002-06-26 → 2002-07-25 (+29d) | 3d → 4d |  | 104d → 83d |  | constraint start no earlier than 2002-06-22 → start no earlier than 2002-07-21; baseline start 2002-06-11 → 2002-07-22; baseline finish 2002-06-11 → 2002-07-25 |
| 48 | AUV Power Systems Meeting | 2002-06-19 A | 2002-06-24 A |  | 0% → 100% | 106d → none |  | resources Hans → Ed |
| 50 | **Cabling and Connectors** |  |  |  | 44% → 72% |  |  | baseline finish 2002-06-21 → 2002-07-23 |
| 51 | Spec Main Power / Comms Cable&Connectors/Penetrators |  |  |  |  |  |  | baseline finish 2002-05-13 → 2002-06-12 |
| 52 | Spec Charging Connector |  | 2002-06-18 → 2002-07-18 (+30d) | 4d → 6d | 50% → 33% | 110.5d → 88d |  | baseline start 2002-05-14 → 2002-06-12; baseline finish 2002-05-17 → 2002-07-18 |
| 53 | Spec Tailcone Comms Cable&Connector/Penetrator |  |  |  |  |  |  | baseline finish 2002-04-29 → 2002-06-05 |
| 59 | Order Connectors |  |  |  |  |  |  | baseline finish 2002-05-15 → 2002-05-20 |
| 60 | **Tail to MVC** |  | 2002-06-07 A |  | 30% → 100% | 107d → none |  | baseline start 2002-05-09 → 2002-06-04; baseline finish 2002-05-09 → 2002-06-07 |
| 61 | Section Interconnect |  | 2002-06-07 A |  | 30% → 100% | 107d → none |  | baseline start 2002-05-09 → 2002-06-04; baseline finish 2002-05-09 → 2002-06-07 |
| 62 | Documetation package on Connectors and Cabling | 2002-06-13 A | 2002-06-26 A |  | 0% → 100% | 104d → none |  | baseline start 2002-06-10 → 2002-06-13; baseline finish 2002-06-21 → 2002-06-26 |
| 63 | Cable Assy @ Seacon | 2002-06-18 A |  |  | 0% → 35% |  |  | baseline start none → 2002-06-18; baseline finish none → 2002-07-23 |
| 65 | **Main Vehicle Computer** |  |  |  | 44% → 52% |  |  | baseline finish 2002-09-19 → 2002-10-04 |
| 66 | **Electronics** |  |  |  | 60% → 68% |  |  | baseline finish 2002-06-05 → 2002-09-20 |
| 70 | Develop latency test/budget for MVC |  | 2002-06-07 → 2002-07-19 (+42d) |  |  | 117d → 87d |  | baseline start 2002-05-13 → 2002-05-27; baseline finish 2002-05-16 → 2002-07-19 |
| 71 | **Power Board** |  | 2002-06-19 → 2002-07-11 (+22d) | 37.5d → 54d | 87% → 96% | 99.5d → 83d |  | baseline finish 2002-05-29 → 2002-07-11 |
| 73 | Design |  |  |  |  |  |  | baseline finish 2002-05-23 → 2002-06-13 |
| 74 | Order |  |  |  |  |  |  | baseline start 2002-05-24 → 2002-06-13; baseline finish 2002-05-24 → 2002-06-14 |
| 75 | Build | 2002-06-14 A | 2002-06-18 A |  | 0% → 100% | 99.5d → none |  | baseline start 2002-05-27 → 2002-06-14; baseline finish 2002-05-28 → 2002-06-18 |
| 76 | Test | 2002-06-18 → 2002-07-11 (+23d) | 2002-06-19 → 2002-07-11 (+22d) |  |  | 99.5d → 83d |  | constraint none → start no earlier than 2002-07-11; baseline start 2002-05-29 → 2002-07-11; baseline finish 2002-05-29 → 2002-07-11 |
| 77 | **RF Modem** |  | 2002-05-15 → 2002-06-27 A (+43d) | 44d → 75d | 71% → 100% | 134d → none |  | baseline finish 2002-05-15 → 2002-06-27 |
| 79 | Purchase | 2002-05-14 → 2002-06-26 A (+43d) | 2002-05-15 → 2002-06-27 A (+43d) |  | 0% → 100% | 134d → none |  | constraint start no earlier than 2002-05-14 → start no earlier than 2002-06-26; baseline start 2002-05-14 → 2002-06-26; baseline finish 2002-05-15 → 2002-06-27 |
| 80 | **Acoustic Modem** |  |  |  |  |  |  | baseline start 2002-05-17 → 2002-09-16; baseline finish 2002-05-20 → 2002-09-20 |
| 81 | Evaluate |  |  |  |  |  |  | baseline start 2002-05-17 → 2002-09-16; baseline finish 2002-05-17 → 2002-09-17 |
| 82 | Purchase |  |  |  |  |  |  | baseline start 2002-05-20 → 2002-09-18; baseline finish 2002-05-20 → 2002-09-20 |
| 83 | **GPS** | 2002-06-10 A → 2002-07-06 A (+26d) | 2002-06-28 → 2002-07-26 (+28d) |  | 0% → 20% | 92d → 72d |  | baseline start 2002-05-16 → 2002-06-10; baseline finish 2002-06-05 → 2002-06-28 |
| 84 | Evaluate GPS Position Fix Problem | 2002-06-10 A → 2002-07-06 A (+26d) | 2002-06-21 → 2002-07-19 (+28d) |  | 0% → 30% | 92d → 72d |  | baseline start 2002-05-16 → 2002-06-10; baseline finish 2002-05-29 → 2002-06-21 |
| 85 | Evaluate GPS Board & Antennae | 2002-06-24 → 2002-07-22 (+28d) | 2002-06-27 → 2002-07-25 (+28d) |  |  | 92d → 72d |  | baseline start 2002-05-30 → 2002-06-24; baseline finish 2002-06-04 → 2002-06-27 |
| 86 | Purchase GPS Board & Antennae | 2002-06-28 → 2002-07-26 (+28d) | 2002-06-28 → 2002-07-26 (+28d) |  |  | 92d → 72d |  | baseline start 2002-06-05 → 2002-06-28; baseline finish 2002-06-05 → 2002-06-28 |
| 90 | Spec and Purcahse DVL |  |  |  |  |  |  | baseline finish 2002-05-20 → 2002-08-09 |
| 91 | **MVC Housing** |  | 2002-07-09 → 2002-08-06 (+28d) | 83d → 103d | 21% → 30% | 85d → 65d |  | baseline finish 2002-06-04 → 2002-07-09 |
| 93 | Design | 2002-06-10 → 2002-07-08 A (+28d) | 2002-06-14 → 2002-07-12 (+28d) |  | 0% → 50% | 85d → 65d |  | constraint start no earlier than 2002-06-09 → start no earlier than 2002-07-08; resources Farley → Robert F; baseline start 2002-05-06 → 2002-06-10; baseline finish 2002-05-10 → 2002-06-14 |
| 94 | Build/Purchase | 2002-06-17 → 2002-07-15 (+28d) | 2002-06-28 → 2002-07-26 (+28d) |  |  | 85d → 65d |  | baseline start 2002-05-13 → 2002-06-17; baseline finish 2002-05-24 → 2002-06-28 |
| 95 | Pressure Test | 2002-07-01 → 2002-07-29 (+28d) | 2002-07-02 → 2002-07-30 (+28d) |  |  | 85d → 65d |  | baseline start 2002-05-27 → 2002-07-01; baseline finish 2002-05-28 → 2002-07-02 |
| 96 | Electronics Packagin Layout | 2002-07-03 → 2002-07-31 (+28d) | 2002-07-09 → 2002-08-06 (+28d) |  |  | 85d → 65d |  | baseline start 2002-05-29 → 2002-07-03; baseline finish 2002-06-04 → 2002-07-09 |
| 97 | **Documentation Package** |  |  |  |  |  |  | baseline start 2002-09-05 → 2002-09-23; baseline finish 2002-09-19 → 2002-10-04 |

| ID | Task | Start | Finish | Duration | Complete | Total float | Predecessors | Other |
| --- | --- | --- | --- | --- | --- | --- | --- | --- |
| 98 | Mechanical |  |  |  |  |  |  | baseline start 2002-09-05 → 2002-09-23; baseline finish 2002-09-06 → 2002-09-24 |
| 99 | Electrical |  |  |  |  |  |  | baseline start 2002-09-05 → 2002-09-23; baseline finish 2002-09-16 → 2002-10-02 |
| 100 | Software |  |  |  |  |  |  | baseline start 2002-09-16 → 2002-09-23; baseline finish 2002-09-17 → 2002-09-24 |
| 101 | Integration |  |  |  |  |  |  | baseline start 2002-09-18 → 2002-10-03; baseline finish 2002-09-19 → 2002-10-04 |
| 114 | **Fairings / Vehicle Mechanical Structure** |  |  |  | 14% → 15% |  |  | baseline finish 2002-07-05 → 2002-10-17 |
| 115 | **L&R System Interface** |  | 2002-08-02 → 2002-09-27 (+56d) | 101d → 141d |  | 77d → 37d |  | baseline finish 2002-07-05 → 2002-08-02 |
| 118 | Design L&R Interface |  |  |  |  |  |  | resources Farley → Drew; baseline start 2002-05-27 → 2002-06-24; baseline finish 2002-06-07 → 2002-07-05 |
| 119 | Build Interface |  |  |  |  |  |  | resources Shop → Brooke OS; baseline start 2002-06-10 → 2002-07-08; baseline finish 2002-06-21 → 2002-07-19 |
| 120 | Assemble Interface |  |  |  |  |  |  | resources ME TECH → Brooke OS; baseline start 2002-06-24 → 2002-07-22; baseline finish 2002-06-28 → 2002-07-26 |
| 121 | L&R test plan | 2002-06-24 → 2002-08-05 (+42d) | 2002-06-27 → 2002-08-08 (+42d) |  |  | 98d → 68d |  | constraint start no earlier than 2002-06-24 → start no earlier than 2002-08-03; baseline start 2002-05-27 → 2002-06-24; baseline finish 2002-05-30 → 2002-06-27 |
| 122 | Integrate and Test L&R Interface | 2002-07-29 → 2002-09-23 (+56d) | 2002-08-02 → 2002-09-27 (+56d) |  |  | 77d → 37d |  | constraint none → start no earlier than 2002-09-22; baseline start 2002-07-01 → 2002-07-29; baseline finish 2002-07-05 → 2002-08-02 |
| 124 | **Joining Ring/Systems** |  |  |  |  |  |  | baseline start 2002-05-10 → 2002-09-02; baseline finish 2002-07-01 → 2002-10-17 |
| 125 | Evaluate joining ring systems |  |  |  |  |  |  | baseline start 2002-05-10 → 2002-09-02; baseline finish 2002-05-13 → 2002-09-03 |
| 126 | Review Concept |  |  |  |  |  |  | baseline start 2002-05-14 → 2002-09-04; baseline finish 2002-05-14 → 2002-09-04 |
| 127 | Final Design |  |  |  |  |  |  | baseline start 2002-05-15 → 2002-09-05; baseline finish 2002-06-04 → 2002-09-25 |
| 128 | Build |  |  |  |  |  |  | baseline start 2002-06-05 → 2002-09-26; baseline finish 2002-06-18 → 2002-10-09 |
| 129 | Assemble |  |  |  |  |  |  | baseline start 2002-06-19 → 2002-10-10; baseline finish 2002-06-21 → 2002-10-14 |
| 130 | Test |  |  |  |  |  |  | baseline start 2002-06-24 → 2002-10-15; baseline finish 2002-06-26 → 2002-10-17 |
| 131 | Test new joining ring system |  |  |  |  |  |  | baseline start 2002-06-27 → 2002-09-17; baseline finish 2002-07-01 → 2002-09-19 |
| 132 | **Deck Handling Equipment** |  |  |  | 28% → 27% |  |  | baseline finish 2002-06-07 → 2002-09-18 |
| 133 | New Cart Design |  |  |  |  |  |  | resources ME TECH → HS Intern; baseline finish 2002-05-24 → 2002-07-05 |
| 134 | New Lifitng Gear |  |  |  |  |  |  | resources ME TECH → HS Intern; baseline finish 2002-05-31 → 2002-07-05 |
| 135 | Sphere Lift Mechanism |  |  |  |  |  |  | baseline start 2002-05-21 → 2002-09-05; baseline finish 2002-06-03 → 2002-09-18 |
| 137 | Lifting I beam in Lab |  | 2002-06-05 → 2002-07-30 (+55d) | 5d → 6d | 50% → 42% | 119d → 80.5d |  |  |
| 138 | Cable trays nad outlets in lab ceiling | 2002-07-15 → 2002-07-29 (+14d) | 2002-07-19 → 2002-08-02 (+14d) |  |  | 87d → 77d |  | constraint start no earlier than 2002-07-14 → start no earlier than 2002-07-27; baseline start 2002-06-03 → 2002-07-15; baseline finish 2002-06-07 → 2002-07-19 |
| 139 | **Sensor & Payload Mounts** |  |  |  |  |  |  | baseline start 2002-05-20 → 2002-06-21; baseline finish 2002-05-28 → 2002-06-27 |
| 140 | Antennaes |  |  |  |  |  |  | baseline start 2002-05-20 → 2002-06-21; baseline finish 2002-05-24 → 2002-06-27 |
| 141 | ORE & various equip |  |  |  |  |  |  | baseline start 2002-05-23 → 2002-06-24; baseline finish 2002-05-28 → 2002-06-27 |
| 142 | **Buoyancy** | 2002-06-13 A | 2002-07-11 → 2002-08-23 (+43d) | 21d → 51.4d | 0% → 9% | 85d → 54.6d |  | baseline start 2002-05-22 → 2002-06-13; baseline finish 2002-06-04 → 2002-07-11 |
| 143 | Tailcone Foam Pack Specification | 2002-06-28 → 2002-07-17 (+19d) | 2002-07-04 → 2002-07-23 (+19d) |  |  | 85d → 72d |  | constraint start no earlier than 2002-06-28 → start no earlier than 2002-07-17; baseline start 2002-05-22 → 2002-06-28; baseline finish 2002-05-28 → 2002-07-04 |
| 144 | Tailcone foam machining | 2002-07-05 → 2002-07-24 (+19d) | 2002-07-11 → 2002-07-30 (+19d) |  |  | 85d → 72d |  | baseline start 2002-05-29 → 2002-07-05; baseline finish 2002-06-04 → 2002-07-11 |
| 145 | Modular trim / ballast systems concept | 2002-06-13 A | 2002-06-24 → 2002-08-23 (+60d) |  | 0% → 20% | 98d → 54.6d |  | baseline start 2002-05-22 → 2002-06-13; baseline finish 2002-05-28 → 2002-06-24 |
| 146 | **Fairing Build** | 2002-07-12 → 2002-08-23 (+42d) | 2002-07-23 → 2002-09-04 (+43d) |  |  | 85d → 54.6d |  | baseline start 2002-06-10 → 2002-07-12; baseline finish 2002-06-26 → 2002-07-23 |
| 147 | Noes section (2 plus 1 spare) | 2002-07-12 → 2002-08-23 (+42d) | 2002-07-23 → 2002-09-04 (+43d) |  |  | 85d → 54.6d |  | baseline start 2002-06-10 → 2002-07-12; baseline finish 2002-06-19 → 2002-07-23 |
| 148 | Midboady (2 plus 1 spare) | 2002-07-12 → 2002-08-23 (+42d) | 2002-07-23 → 2002-09-04 (+43d) |  |  | 85d → 54.6d |  | baseline start 2002-06-13 → 2002-07-12; baseline finish 2002-06-24 → 2002-07-23 |
| 149 | Tail section (2 plus 1 spare) | 2002-07-12 → 2002-08-23 (+42d) | 2002-07-23 → 2002-09-04 (+43d) |  |  | 85d → 54.6d |  | baseline start 2002-06-17 → 2002-07-12; baseline finish 2002-06-26 → 2002-07-23 |
| 151 | **Software** | 2002-06-06 A → 2002-06-29 A (+23d) |  | 119d → 102d |  |  |  | baseline start 2002-06-24 → 2002-06-06 |
| 157 | **GUI** | 2002-06-06 → 2002-09-02 (+88d) | 2002-08-14 → 2002-11-08 (+86d) |  |  | 69d → 7d |  | baseline start 2002-07-02 → 2002-06-06; baseline finish 2002-09-09 → 2002-08-14 |
| 158 | gather requirements | 2002-06-06 → 2002-09-02 (+88d) | 2002-06-12 → 2002-09-06 (+86d) |  |  | 69d → 7d |  | constraint start no earlier than 2002-06-06 → start no earlier than 2002-09-01; baseline start 2002-07-02 → 2002-06-06; baseline finish 2002-07-08 → 2002-06-12 |
| 159 | eval Bluefin GUI | 2002-06-13 → 2002-09-09 (+88d) | 2002-06-26 → 2002-09-20 (+86d) |  |  | 69d → 7d |  | baseline start 2002-07-09 → 2002-06-13; baseline finish 2002-07-22 → 2002-06-26 |
| 160 | develop GUI plan | 2002-06-27 → 2002-09-23 (+88d) | 2002-07-03 → 2002-09-27 (+86d) |  |  | 69d → 7d |  | baseline start 2002-07-23 → 2002-06-27; baseline finish 2002-07-29 → 2002-07-03 |
| 161 | Detail GUI development (TBD) | 2002-07-04 → 2002-09-30 (+88d) | 2002-08-14 → 2002-11-08 (+86d) |  |  | 69d → 7d |  | baseline start 2002-07-30 → 2002-07-04; baseline finish 2002-09-09 → 2002-08-14 |
| 162 | Configuration management on vehicle (config files) |  |  |  |  |  |  | baseline start 2002-08-16 → 2002-07-09; baseline finish 2002-09-05 → 2002-07-29 |
| 163 | **Controls** | 2002-07-19 → 2002-09-02 (+45d) | 2002-09-19 → 2002-11-01 (+43d) |  |  | 43d → 12d |  | baseline start 2002-06-24 → 2002-07-19; baseline finish 2002-08-23 → 2002-09-19 |
| 164 | depth control improvement (long configs) | 2002-07-19 → 2002-09-02 (+45d) | 2002-08-08 → 2002-09-20 (+43d) |  |  | 43d → 12d |  | constraint start no earlier than 2002-07-19 → start no earlier than 2002-08-31; baseline start 2002-06-24 → 2002-07-19; baseline finish 2002-07-12 → 2002-08-08 |
| 165 | sway / yaw control coupling (heave/ pitch too) | 2002-08-09 → 2002-09-23 (+45d) | 2002-08-22 → 2002-10-04 (+43d) |  |  | 43d → 12d |  | baseline start 2002-07-15 → 2002-08-09; baseline finish 2002-07-26 → 2002-08-22 |
| 166 | slow speed dynamics for control | 2002-08-23 → 2002-10-07 (+45d) | 2002-09-19 → 2002-11-01 (+43d) |  |  | 43d → 12d |  | baseline start 2002-07-29 → 2002-08-23; baseline finish 2002-08-23 → 2002-09-19 |
| 167 | **Navigation Software** | 2002-09-23 A → 2002-06-29 A (-86d) |  | 42d → 102d |  |  |  |  |
| 172 | DVL driver enhancements for PD5 | 2002-10-09 A → 2002-06-29 A (-102d) | 2002-10-29 → 2002-07-19 (-102d) |  |  | 15d → 87d | 169 → none |  |
| 177 | **Vehicle Integration and Test** | 2002-07-18 → 2002-09-02 (+46d) | 2002-09-04 → 2002-10-21 (+47d) | 35d → 36d |  | 53d → 20d |  | baseline start 2002-06-10 → 2002-07-18; baseline finish 2002-08-02 → 2002-09-04 |
| 178 | Tailcone Assembly | 2002-07-18 → 2002-09-02 (+46d) | 2002-07-24 → 2002-09-06 (+44d) |  |  | 62d → 30d |  | constraint start no earlier than 2002-07-18 → start no earlier than 2002-09-02; baseline start 2002-06-10 → 2002-07-18; baseline finish 2002-06-14 → 2002-07-24 |
| 179 | Tailcone Test | 2002-07-25 → 2002-09-09 (+46d) | 2002-07-30 → 2002-09-12 (+44d) |  |  | 62d → 30d |  | baseline start 2002-06-17 → 2002-07-25; baseline finish 2002-06-20 → 2002-07-30 |
| 180 | Battery Midbody Integration | 2002-07-31 → 2002-09-11 (+42d) | 2002-08-06 → 2002-09-17 (+42d) |  |  | 53d → 23d |  | constraint start no earlier than 2002-07-31 → start no earlier than 2002-09-11; baseline start 2002-06-17 → 2002-07-31; baseline finish 2002-06-21 → 2002-08-06 |
| 181 | Battery Midbody Test | 2002-08-07 → 2002-09-18 (+42d) | 2002-08-12 → 2002-09-23 (+42d) |  |  | 53d → 23d |  | baseline start 2002-06-24 → 2002-08-07; baseline finish 2002-06-27 → 2002-08-12 |
| 182 | ALTEX Nose Payload Assembly/Upgrade | 2002-07-19 → 2002-09-09 (+52d) | 2002-07-25 → 2002-09-13 (+50d) |  |  | 56d → 20d |  | constraint start no earlier than 2002-07-19 → start no earlier than 2002-09-08; baseline start 2002-06-17 → 2002-07-19; baseline finish 2002-06-21 → 2002-07-25 |
| 183 | Science Payload Assembly | 2002-07-26 → 2002-09-16 (+52d) | 2002-08-02 → 2002-09-23 (+52d) |  |  | 56d → 20d |  | baseline start 2002-06-24 → 2002-07-26; baseline finish 2002-07-01 → 2002-08-02 |
| 184 | Payload Test | 2002-08-05 → 2002-09-24 (+50d) | 2002-08-07 → 2002-09-26 (+50d) |  |  | 56d → 20d |  | baseline start 2002-07-02 → 2002-08-05; baseline finish 2002-07-04 → 2002-08-07 |
| 185 | Integrated Vehcile Deck Assembly | 2002-08-13 → 2002-09-27 (+45d) | 2002-08-14 → 2002-09-30 (+47d) |  |  | 53d → 20d |  | baseline start 2002-07-05 → 2002-08-13; baseline finish 2002-07-08 → 2002-08-14 |
| 186 | Vehicle Ballasting | 2002-08-15 → 2002-10-01 (+47d) | 2002-08-15 → 2002-10-01 (+47d) |  |  | 53d → 20d |  | baseline start 2002-07-09 → 2002-08-15; baseline finish 2002-07-09 → 2002-08-15 |
| 187 | Integrated Vehicle Deck Test | 2002-08-16 → 2002-10-02 (+47d) | 2002-08-20 → 2002-10-04 (+45d) |  |  | 53d → 20d |  | baseline start 2002-07-10 → 2002-08-16; baseline finish 2002-07-12 → 2002-08-20 |
| 188 | Integrated Vehicle Tank Test | 2002-08-21 → 2002-10-07 (+47d) | 2002-08-27 → 2002-10-11 (+45d) |  |  | 53d → 20d |  | baseline start 2002-07-15 → 2002-08-21; baseline finish 2002-07-19 → 2002-08-27 |
| 189 | Integrated Vehicle Sea Trials | 2002-08-28 → 2002-10-14 (+47d) | 2002-09-04 → 2002-10-21 (+47d) |  |  | 53d → 20d |  | baseline start 2002-07-22 → 2002-08-28; baseline finish 2002-08-02 → 2002-09-04 |
| 191 | **CTD Science Payload Core** |  | 2002-09-05 → 2002-10-22 (+47d) | 51d? → 84d? |  | 53d → 20d |  | baseline start 2002-06-20 → 2002-06-27; baseline finish 2002-08-05 → 2002-09-05 |
| 192 | Repair/Replace nose fairing | 2002-07-22 → 2002-07-12 (-10d) | 2002-07-24 → 2002-07-16 (-8d) |  |  | 78d → 84d |  | constraint start no earlier than 2002-07-20 → start no earlier than 2002-07-12; baseline start 2002-06-20 → 2002-07-22; baseline finish 2002-06-24 → 2002-07-24 |
| 193 | recable Dcon to comms and pwr bus | 2002-07-29 → 2002-07-18 (-11d) | 2002-08-07 → 2002-07-29 (-9d) |  |  | 70d → 77d |  | constraint start no earlier than 2002-07-27 → start no earlier than 2002-07-18; baseline start 2002-06-21 → 2002-07-29; baseline finish 2002-07-02 → 2002-08-07 |
| 194 | Design HS2 Mount | 2002-07-25 → 2002-07-17 (-8d) | 2002-07-26 → 2002-07-18 (-8d) |  |  | 78d → 84d |  | baseline start 2002-06-25 → 2002-07-25; baseline finish 2002-06-26 → 2002-07-26 |
| 195 | Build HS2 Mount | 2002-07-29 → 2002-07-19 (-10d) | 2002-07-30 → 2002-07-22 (-8d) |  |  | 78d → 84d |  | baseline start 2002-06-27 → 2002-07-29; baseline finish 2002-06-28 → 2002-07-30 |
| 196 | Assembly HS2 Mount | 2002-07-31 → 2002-07-23 (-8d) | 2002-08-01 → 2002-07-24 (-8d) |  |  | 78d → 84d |  | baseline start 2002-07-01 → 2002-07-31; baseline finish 2002-07-02 → 2002-08-01 |
| 199 | repair flow sensor #2 | 2002-08-08 → 2002-07-30 (-9d) | 2002-08-12 → 2002-08-01 (-11d) |  |  | 70d → 77d |  | baseline start 2002-07-03 → 2002-08-08; baseline finish 2002-07-05 → 2002-08-12 |
| 200 | test integrated CTD Payload | 2002-09-05 → 2002-10-22 (+47d) | 2002-09-05 → 2002-10-22 (+47d) |  |  | 53d → 20d |  | baseline start 2002-08-05 → 2002-09-05; baseline finish 2002-08-05 → 2002-09-05 |

| ID | Task | Start | Finish | Duration | Total float | Other |
| --- | --- | --- | --- | --- | --- | --- |
| 202 | **CTD Extension for Ryan/Haddock** |  |  |  |  | baseline start 2002-06-03 → 2002-06-27; baseline finish 2002-07-01 → 2002-07-25 |
| 203 | Design LISST pump assy |  |  |  |  | baseline start 2002-06-03 → 2002-06-27; baseline finish 2002-06-06 → 2002-07-02 |
| 204 | Fab LISST pump assy |  |  |  |  | baseline start 2002-06-07 → 2002-07-03; baseline finish 2002-06-13 → 2002-07-09 |
| 205 | Assy LISST pump into vehicle |  |  |  |  | baseline start 2002-06-14 → 2002-07-10; baseline finish 2002-06-17 → 2002-07-11 |
| 206 | Design LISST mount |  |  |  |  | baseline start 2002-06-07 → 2002-07-03; baseline finish 2002-06-13 → 2002-07-09 |
| 207 | Fab LISST Mount |  |  |  |  | baseline start 2002-06-14 → 2002-07-10; baseline finish 2002-06-20 → 2002-07-16 |
| 208 | Assy LISST mount |  |  |  |  | baseline start 2002-06-21 → 2002-07-17; baseline finish 2002-06-24 → 2002-07-18 |
| 209 | Cable LISST to Dcon |  |  |  |  | baseline start 2002-06-25 → 2002-07-19; baseline finish 2002-06-25 → 2002-07-19 |
| 210 | Write Test Driver for LISST |  |  |  |  | baseline start 2002-06-25 → 2002-07-19; baseline finish 2002-07-01 → 2002-07-25 |
| 211 | Design Bathypho mount |  |  |  |  | baseline start 2002-06-05 → 2002-07-03; baseline finish 2002-06-10 → 2002-07-08 |
| 212 | Fab Bathypho mount |  |  |  |  | baseline start 2002-06-11 → 2002-07-09; baseline finish 2002-06-17 → 2002-07-15 |
| 213 | Assy Bathypho mount |  |  |  |  | baseline start 2002-06-18 → 2002-07-16; baseline finish 2002-06-19 → 2002-07-17 |
| 214 | Cable Bathypho to Dcon |  |  |  |  | baseline start 2002-06-20 → 2002-07-18; baseline finish 2002-06-20 → 2002-07-18 |
| 215 | Retest driver for Bathypho (already written) |  |  |  |  | baseline start 2002-06-21 → 2002-07-19; baseline finish 2002-06-25 → 2002-07-23 |
| 217 | **Ryan / Haddock Cruise Prep** | 2002-08-05 → 2002-06-26 (-40d) | 2002-08-22 → 2002-08-29 (+7d) | 14d → 47d? | 63d → 58d | constraint start no earlier than 2002-08-05 → none; baseline start 2002-07-29 → 2002-08-05; baseline finish 2002-08-15 → 2002-08-22 |
